# Design-Build CSTv1.3

How a schedule from Primavera P6 changed from version to version. A marks actual dates.

## Version 1 (data date 2023-01-01, saved 2024-09-24, file DB CST 1.3.xer)

| ID | WBS | Task | Duration | Start | Finish | Predecessors | Total float | Constraint |
| --- | --- | --- | --- | --- | --- | --- | --- | --- |
|  | DB CCTD 1.0.1 | **Design-Build Contract Procurement** |  | 2023-01-03 | 2023-07-22 |  |  |  |
| ContractNo_Prelim |  | BTC Plans/Specs/Spec. Prov. accepted by MassDOT | 0d | 2023-01-03 | 2023-01-03 |  | 70d |  |
| ContractNo_Prelim10 |  | FHWA Review BTC Plans/Specs/Spec. Provisions | 30d | 2023-01-03 | 2023-02-01 | ContractNo_Prelim SS | 100d |  |
| ContractNo_LOI |  | Advertise Request for Letters-of-Interest (LOI) | 0d | 2023-01-07 | 2023-01-07 |  | 6d |  |
| ContractNo_LOIP |  | Letters-of-Interest (LOI) Procurement | 40d | 2023-01-07 | 2023-02-15 | ContractNo_LOI SS | 37d |  |
| ContractNo_RFP20 |  | FHWA Concurrance to Advertise | 0d | 2023-02-01 | 2023-02-01 | ContractNo_Prelim10 FF | 70d |  |
| ContractNo_LOID |  | Letters-of-Interest (LOI) Due | 0d | 2023-02-15 | 2023-02-15 | ContractNo_LOIP FF | 26d |  |
| ContractNo_RFQ |  | Issue Request for Qualifications (RFQ) | 0d | 2023-02-16 | 2023-02-16 | ContractNo_LOID | 26d |  |
| ContractNo_RFQP |  | Statement of Qualifications Prepared | 28d | 2023-02-16 | 2023-03-15 | ContractNo_RFQ SS | 37d |  |
| ContractNo_RFQD |  | Statement of Qualifications Due | 0d | 2023-03-15 | 2023-03-15 | ContractNo_RFQP FF | 26d |  |
| ContractNo_ShList |  | Shortlist of Proposers Selected/Notified | 20d | 2023-03-16 | 2023-04-04 | ContractNo_RFQD | 39d |  |
| ContractNo_RFP10 |  | Advertise Request for Proposals | 0d | 2023-04-08 | 2023-04-08 | ContractNo_ShList, ContractNo_RFP20 | 6d |  |
| ContractNo_RFP |  | Release Request for Proposals (RFP) | 0d | 2023-04-10 | 2023-04-10 | ContractNo_RFP10 SS | 26d |  |
| ContractNo_RFPP |  | Proposers Prepare Proposals | 43d | 2023-04-10 | 2023-05-22 | ContractNo_RFP SS | 37d |  |
| ContractNo_RFPP20 |  | Pre-Proposal Meeting | 1d | 2023-04-10 | 2023-04-10 | ContractNo_RFPP SS | 44d |  |
| ContractNo_RFPP30 |  | ATC Meetings | 3d | 2023-04-11 | 2023-04-13 | ContractNo_RFPP20 | 44d |  |
| ContractNo_RFPP50 |  | ATC Proposals Due | 1d | 2023-04-14 | 2023-04-14 | ContractNo_RFPP30 | 44d |  |
| ContractNo_RFPP40 |  | Final RFP Questions Due | 1d | 2023-05-15 | 2023-05-15 | ContractNo_RFPP30, ContractNo_RFPP50 | 25d | as late as possible |
| ContractNo_RFPP10 |  | Technical and Price Proposals Due | 0d | 2023-05-22 | 2023-05-22 | ContractNo_RFPP FF, ContractNo_RFPP40 FF+5d | 25d |  |
| ContractNo_RFPD00 |  | Oral Presentation of Design-Build Proposals | 2d | 2023-05-31 | 2023-06-01 | ContractNo_RFPP, ContractNo_RFPP10 FS+5d | 25d |  |
| ContractNo_RFPD10 |  | Scoring of Technical Proposals | 2d | 2023-06-02 | 2023-06-05 | ContractNo_RFPD00 | 25d |  |
| ContractNo_BID |  | Public Price Bid Opening | 0d | 2023-06-06 | 2023-06-06 | ContractNo_RFPD10 FF+1d | 25d |  |
| ContractNo_NOA |  | Issue Notice of Award\Project Start | 45d | 2023-06-08 | 2023-07-22 | ContractNo_BID FS+1d | 39d |  |
|  | 1 | **Milestones** |  | 2023-07-22 | 2025-07-08 |  |  |  |
|  | 1 | **General** |  | 2023-07-22 | 2025-07-08 |  |  |  |
| ContractNo_NTP |  | Issue Design-Builder Notice-to-Proceed (NTP) | 0d | 2023-07-22 | 2023-07-22 | ContractNo_NOA | 39.67d |  |
| ContractNo_AR01 |  | Access Restraint: Relocate Util before Bridge Demo | 0d | 2024-04-10 | 2024-04-10 | ContractNo_1030 FF, ContractNo_U430 | 97.87d |  |
| ContractNo_MS03 |  | MS#03 - Full Beneficial Use (FBU) | 0d | 2025-04-23 | 2025-04-23 | ContractNo_C320 FF, ContractNo_C885 FF, ContractNo_MS04 FF, ContractNo_1000 FF, ContractNo_U480 FF | 0.67d | finish on or before 2026-10-01 |
| ContractNo_MS04 |  | MS#04 - Perform Final Traffic Move | 0d | 2025-04-23 | 2025-04-23 | ContractNo_C885 FF | 0.67d |  |
| ContractNo_MS02 |  | MS#02 - Substantial Completion (SC) | 0d | 2025-05-22 | 2025-05-22 | ContractNo_C340 FF, ContractNo_C360 SF | 0.67d | finish on or before 2026-10-01 |
| ContractNo_MS01 |  | MS#01 - Field Completion (CFC) | 0d | 2025-07-08 | 2025-07-08 | ContractNo_C470, ContractNo_1020 FF, ContractNo_C330 FF | 0d | finish on or before 2026-11-15 |
|  | 2 | **Durations** |  | 2023-07-22 | 2025-07-08 |  |  |  |
| ContractNo_1000 |  | Construction Contract Duration (NTP to FBU) | 641d | 2023-07-22 | 2025-04-23 | ContractNo_NTP SS | 0.67d |  |
| ContractNo_1010 |  | Construction Contract Duration (NTP to SC) | 670d | 2023-07-22 | 2025-05-22 | ContractNo_MS02 FF, ContractNo_NTP SS | 0.67d |  |
| ContractNo_1020 |  | Construction Contract Duration (NTP to CFC) | 717d | 2023-07-22 | 2025-07-08 | ContractNo_NTP SS | 0d |  |
| ContractNo_1030 |  | Construction Contract Duration (NTP to AR01) | 262.8d | 2023-07-22 | 2024-04-10 | ContractNo_NTP SS | 97.87d |  |
|  | 2 | **Submittals & Procurements** |  | 2023-07-24 | 2024-12-05 |  |  |  |
|  | 1 | **Early Release Design Packages** |  | 2023-07-24 | 2024-10-17 |  |  |  |
|  | 3 | **Geotechnical Report** |  | 2023-07-24 | 2023-11-17 |  |  |  |
| ContractNo_2640 |  | Prepare & Submit Subsurface Investigation Plan | 10d | 2023-07-24 | 2023-08-04 | ContractNo_NTP SS | 363d |  |
| ContractNo_2660 |  | Review & Approve Subsurface Investigation Plan | 10d | 2023-08-05 | 2023-08-14 | ContractNo_2640 | 532d |  |
| ContractNo_2650 |  | Schedule/Perform Geotech Borings & Test Pits | 30d | 2023-08-15 | 2023-09-26 | ContractNo_2640, ContractNo_2660 | 362d |  |
| ContractNo_1680 |  | Prepare Geotechnical Report | 9d | 2023-09-27 | 2023-10-10 | ContractNo_NTP SS, ContractNo_2650 | 362d |  |
| ContractNo_1950 |  | Schedule & Conduct OTS Review - Geotechnical Report | 2d | 2023-10-11 | 2023-10-12 | ContractNo_1680 | 362d |  |
| ContractNo_1940 |  | Submit Geotechnical Report | 4d | 2023-10-13 | 2023-10-18 | ContractNo_1950 | 362d |  |
| ContractNo_2050 |  | Review & Approve Geotechnical Report | 30d | 2023-10-19 | 2023-11-17 | ContractNo_1940 | 552d |  |
|  | 1 | **Drilled Shafts** |  | 2023-10-19 | 2024-01-20 |  |  |  |
| ContractNo_1740 |  | Prepare Drilled Shafts Design | 10d | 2023-10-19 | 2023-11-01 | ContractNo_1940 | 362d |  |
| ContractNo_1990 |  | Schedule & Conduct OTS Review - Drilled Shafts Design | 1d | 2023-11-02 | 2023-11-02 | ContractNo_1740 | 362d |  |
| ContractNo_1980 |  | Submit Drilled Shafts Design | 3d | 2023-11-03 | 2023-11-07 | ContractNo_1990 | 362d |  |
| ContractNo_2060 |  | Review & Approve Drilled Shafts Design | 30d | 2023-11-08 | 2023-12-07 | ContractNo_1980 | 532d |  |
| ContractNo_1750 |  | Comment Resolution & Reissue Drilled Shafts Design | 10d | 2023-12-08 | 2023-12-21 | ContractNo_2060, ContractNo_2050 | 363d |  |
| ContractNo_1890 |  | Procure Drilled Shaft Casings | 30d | 2023-12-22 | 2024-01-20 | ContractNo_1750 | 535d |  |
|  | 4 | **Substructure Rebar** |  | 2023-07-24 | 2024-01-29 |  |  |  |
| ContractNo_1780 |  | Prepare Early Release - Substructure Design | 90d | 2023-07-24 | 2023-11-29 | ContractNo_NTP SS | 359d |  |
| ContractNo_2010 |  | Schedule & Conduct OTS Review - Early Release - Substructure Design | 7d | 2023-11-30 | 2023-12-08 | ContractNo_1780 | 359d |  |
| ContractNo_2000 |  | Submit Early Release - Substructure Design | 4d | 2023-12-11 | 2023-12-14 | ContractNo_2010 | 359d |  |
| ContractNo_2070 |  | Review & Approve Early Release - Substructure Design | 30d | 2023-12-15 | 2024-01-13 | ContractNo_2000 | 527d |  |
| ContractNo_1790 |  | Comment Resolution & Reissue Early Release - Substructure Design | 10d | 2024-01-16 | 2024-01-29 | ContractNo_2070 | 359d |  |
|  | 2 | **Structural Steel** |  | 2023-07-24 | 2024-10-17 |  |  |  |
| ContractNo_1760 |  | Prepare Early Release - Superstructure Design | 90d | 2023-07-24 | 2023-11-29 | ContractNo_NTP SS | 28d |  |
| ContractNo_1970 |  | Schedule & Conduct OTS Review - Early Release - Superstructure Design | 1d | 2023-11-30 | 2023-11-30 | ContractNo_1760, ContractNo_1700, ContractNo_1820 | 28d |  |
| ContractNo_1960 |  | Submit Early Release - Superstructure Design | 1d | 2023-12-01 | 2023-12-01 | ContractNo_1700, ContractNo_1970 | 28d |  |
| ContractNo_1770 |  | Review & Approve Early Release - Superstructure Design | 30d | 2023-12-02 | 2023-12-31 | ContractNo_1760, ContractNo_1960 | 42d |  |
| ContractNo_2040 |  | Comment Resolution & Reissue Early Release - Superstructure Design | 5d | 2024-01-02 | 2024-01-08 | ContractNo_1770 | 28d |  |
| ContractNo_1710 |  | Prepare & Submit Structural Steel Shop Drawings | 40d | 2024-01-09 | 2024-03-06 | ContractNo_1770, ContractNo_2040 | 28d |  |
| ContractNo_1720 |  | Review & Approve Structural Steel Shop Drawings | 30d | 2024-03-07 | 2024-04-05 | ContractNo_1710 | 41d |  |
| ContractNo_1730 |  | Procure Structural Steel Stage 1 | 75d | 2024-04-06 | 2024-06-19 | ContractNo_1720 | 41d |  |
| ContractNo_1800 |  | Procure Structural Steel Stage 2 | 120d | 2024-06-20 | 2024-10-17 | ContractNo_1730 | 264d |  |
|  | 9 | **Bridge Bearings Design** |  | 2024-01-09 | 2024-03-07 |  |  |  |

| ID | WBS | Task | Duration | Start | Finish | Predecessors | Total float |
| --- | --- | --- | --- | --- | --- | --- | --- |
| ContractNo_1830 |  | Prepare & Submit Early Release Bridge Bearings | 20d | 2024-01-09 | 2024-02-06 | ContractNo_2040 | 333d |
| ContractNo_1840 |  | Review & Approve Early Release Bridge Bearings | 30d | 2024-02-07 | 2024-03-07 | ContractNo_1830 | 488d |
|  | 10 | **Bridge Scuppers Design** |  | 2024-01-09 | 2024-04-12 |  |  |
| ContractNo_1850 |  | Prepare & Submit Bridge Scupper Design | 45d | 2024-01-09 | 2024-03-13 | ContractNo_2040 | 308d |
| ContractNo_1860 |  | Review & Approve Bridge Scupper Design | 30d | 2024-03-14 | 2024-04-12 | ContractNo_1850 | 452d |
|  | 11 | **Bridge Joint Design** |  | 2024-01-09 | 2024-04-12 |  |  |
| ContractNo_1870 |  | Prepare & Submit Bridge Joint Design | 45d | 2024-01-09 | 2024-03-13 | ContractNo_2040 | 308d |
| ContractNo_1880 |  | Review & Approve Bridge Joint Design | 30d | 2024-03-14 | 2024-04-12 | ContractNo_1870 | 452d |
|  | 2 | **Projectwide Submittals** |  | 2023-07-24 | 2024-01-04 |  |  |
|  | 1 | **Project Schedule** |  | 2023-07-24 | 2024-01-04 |  |  |
| ContractNo_2080 |  | Prepare & Submit Initial Baseline Project Schedule (Logic Only) | 40d | 2023-07-24 | 2023-09-18 | ContractNo_NTP SS, ContractNo_PCM2 SF+10d | 376d |
| ContractNo_2090 |  | Review & Comment on Initial Baseline Project Schedule (Logic Only) | 30d | 2023-09-19 | 2023-10-18 | ContractNo_2080 | 551d |
| ContractNo_2220 |  | Prepare & Submit Baseline Schedule (Logic Only) (Rev 1) | 15d | 2023-10-19 | 2023-11-08 | ContractNo_2090 | 375d |
| ContractNo_2230 |  | Review & Comment on Baseline Schedule (Logic Only (Rev 1) | 15d | 2023-11-09 | 2023-11-23 | ContractNo_2220 | 551d |
| ContractNo_2620 |  | Prepare & Submit Cost & Resource Loaded Baseline Schedule | 15d | 2023-11-24 | 2023-12-14 | ContractNo_2230 | 375d |
| ContractNo_2630 |  | Review & Approve Cost & Resource Loaded Baseline Schedule | 21d | 2023-12-15 | 2024-01-04 | ContractNo_2620 | 551d |
|  | 2 | **Project Management Plan** |  | 2023-07-24 | 2023-10-01 |  |  |
| ContractNo_2100 |  | Prepare & Submit Project Management Plan | 30d | 2023-07-24 | 2023-09-01 | ContractNo_NTP SS | 439d |
| ContractNo_2110 |  | Review & Approve Project Management Plan | 30d | 2023-09-02 | 2023-10-01 | ContractNo_2100 | 646d |
|  | 4 | **Public Participation Plan** |  | 2023-07-24 | 2023-10-01 |  |  |
| ContractNo_2120 |  | Prepare & Submit Public Participation Plan | 30d | 2023-07-24 | 2023-09-01 | ContractNo_NTP SS | 439d |
| ContractNo_2160 |  | Setup Project Webpage | 20d | 2023-07-24 | 2023-08-18 | ContractNo_NTP SS | 469d |
| ContractNo_2130 |  | Review & Approve Public Participation Plan | 30d | 2023-09-02 | 2023-10-01 | ContractNo_2120 | 646d |
|  | 5 | **Health & Safety Plan** |  | 2023-07-24 | 2023-09-17 |  |  |
| ContractNo_2140 |  | Prepare & Submit Health & Safety Plan | 20d | 2023-07-24 | 2023-08-18 | ContractNo_NTP SS | 449d |
| ContractNo_2150 |  | Review & Approve Health & Safety Plan | 30d | 2023-08-19 | 2023-09-17 | ContractNo_2140 | 660d |
|  | 3 | **Environmental Submittals** |  | 2023-07-24 | 2023-12-29 |  |  |
|  | 8 | **Groundwater & Soil Management Plan** |  | 2023-07-24 | 2023-10-25 |  |  |
| ContractNo_2520 |  | Prepare & Submit Groundwater & Soil Management Plan | 45d | 2023-07-24 | 2023-09-25 | ContractNo_NTP SS | 167d |
| ContractNo_2530 |  | Review & Approve Groundwater & Soil Management Plan | 30d | 2023-09-26 | 2023-10-25 | ContractNo_2520 | 244d |
|  | 10 | **Noise Control Plan** |  | 2023-07-24 | 2023-10-01 |  |  |
| ContractNo_2540 |  | Prepare & Submit Noise Control Plan | 30d | 2023-07-24 | 2023-09-01 | ContractNo_NTP SS | 439d |
| ContractNo_2550 |  | Review & Approve Noise Control Plan | 30d | 2023-09-02 | 2023-10-01 | ContractNo_2540 | 646d |
|  | 11 | **Dust Control Plan** |  | 2023-07-24 | 2023-10-01 |  |  |
| ContractNo_2560 |  | Prepare & Submit Dust Control Plan | 30d | 2023-07-24 | 2023-09-01 | ContractNo_NTP SS | 439d |
| ContractNo_2570 |  | Review & Approve Dust Control Plan | 30d | 2023-09-02 | 2023-10-01 | ContractNo_2560 | 646d |
|  | 13 | **Invasive Species Management Plan** |  | 2023-07-24 | 2023-10-18 |  |  |
| ContractNo_2600 |  | Prepare & Submit Invasive Species Management Plan | 40d | 2023-07-24 | 2023-09-18 | ContractNo_NTP SS | 429d |
| ContractNo_2610 |  | Review & Approve Invasive Species Management Plan | 30d | 2023-09-19 | 2023-10-18 | ContractNo_2600 | 629d |
|  | 12 | **Dredge Material Plan** |  | 2023-07-24 | 2023-12-29 |  |  |
| ContractNo_2580 |  | Prepare & Submit Dredge Material Plan | 90d | 2023-07-24 | 2023-11-29 | ContractNo_NTP SS | 379d |
| ContractNo_2590 |  | Review & Approve Dredge Material Plan | 30d | 2023-11-30 | 2023-12-29 | ContractNo_2580 | 557d |
|  | 4 | **Design Submittals** |  | 2023-07-24 | 2024-12-05 |  |  |
|  | 1 | **Formal Bridge Sketch Plan** |  | 2023-07-24 | 2023-11-02 |  |  |
| ContractNo_1690 |  | Prepare Formal Bridge Sketch Plan | 35d | 2023-07-24 | 2023-09-11 | ContractNo_NTP SS | 46d |
| ContractNo_1930 |  | Schedule & Conduct OTS Review - Formal Bridge Sketch Plan | 2d | 2023-09-12 | 2023-09-13 | ContractNo_1690 | 46d |
| ContractNo_1920 |  | Submit Formal Bridge Sketch Plan | 4d | 2023-09-14 | 2023-09-19 | ContractNo_1930 | 46d |
| ContractNo_2020 |  | Review & Approve Formal Bridge Sketch Plan | 30d | 2023-09-20 | 2023-10-19 | ContractNo_1920 | 68d |
| ContractNo_1700 |  | Comment Resolution & Reissue Formal Bridge Sketch Plan | 10d | 2023-10-20 | 2023-11-02 | ContractNo_1920, ContractNo_2020 | 46d |
|  | 2 | **First Structural Design - Bridge** |  | 2023-10-20 | 2024-02-02 |  |  |
| ContractNo_2670 |  | Prepare First Structural Bridge | 37d | 2023-10-20 | 2023-12-12 | ContractNo_2020 | 142d |
| ContractNo_2770 |  | Schedule & Conduct OTS Review - First Structural Bridge | 2d | 2023-12-13 | 2023-12-14 | ContractNo_2670 | 142d |
| ContractNo_2780 |  | Finalize First Structural Bridge | 2d | 2023-12-15 | 2023-12-18 | ContractNo_2770 | 142d |
| ContractNo_2790 |  | Formal QC Review First Structural Bridge | 3d | 2023-12-19 | 2023-12-21 | ContractNo_2780 | 142d |
| ContractNo_2800 |  | Submit First Structural Bridge | 1d | 2023-12-22 | 2023-12-22 | ContractNo_2790 | 142d |
| ContractNo_2970 |  | Review & Approve First Structural Bridge | 30d | 2023-12-23 | 2024-01-21 | ContractNo_2800 | 211d |
| ContractNo_2680 |  | Comment Resolution & Reissue First Structural Bridge | 10d | 2024-01-22 | 2024-02-02 | ContractNo_2970 | 146d |
|  | 5 | **Second Structural Design - Bridge** |  | 2024-02-05 | 2024-04-05 |  |  |
| ContractNo_2710 |  | Prepare Second Structural Bridge | 5d | 2024-02-05 | 2024-02-09 | ContractNo_2680 | 274d |
| ContractNo_2850 |  | Schedule & Conduct OTS Review - Second Structural Bridge | 2d | 2024-02-12 | 2024-02-13 | ContractNo_2710 | 274d |
| ContractNo_2860 |  | Finalize Second Structural Bridge | 2d | 2024-02-14 | 2024-02-15 | ContractNo_2850 | 274d |
| ContractNo_2870 |  | Formal QC Review Second Structural Bridge | 3d | 2024-02-16 | 2024-02-21 | ContractNo_2860 | 274d |
| ContractNo_2880 |  | Submit Second Structural Bridge | 1d | 2024-02-22 | 2024-02-22 | ContractNo_2870 | 274d |
| ContractNo_2990 |  | Review & Approve Second Structural Bridge | 30d | 2024-02-23 | 2024-03-23 | ContractNo_2880 | 402d |
| ContractNo_2720 |  | Comment Resolution & Reissue Second Structural Bridge | 10d | 2024-03-25 | 2024-04-05 | ContractNo_2710, ContractNo_2880, ContractNo_2990 | 274d |
|  | 4 | **75% Design - Highway** |  | 2024-02-05 | 2024-07-19 |  |  |
| ContractNo_2690 |  | Prepare 75% Design - Highway | 75d | 2024-02-05 | 2024-05-21 | ContractNo_2680 | 146d |
| ContractNo_2810 |  | Schedule & Conduct OTS Review - 75% Design - Highway | 2d | 2024-05-22 | 2024-05-23 | ContractNo_2690 | 146d |
| ContractNo_2820 |  | Finalize 75% Design - Highway | 2d | 2024-05-24 | 2024-05-28 | ContractNo_2810 | 146d |
| ContractNo_2830 |  | Formal QC Review 75% Design - Highway | 3d | 2024-05-29 | 2024-05-31 | ContractNo_2820 | 146d |

| ID | WBS | Task | Duration | Start | Finish | Predecessors | Total float |
| --- | --- | --- | --- | --- | --- | --- | --- |
| ContractNo_2840 |  | Submit 75% Design - Highway | 1d | 2024-06-03 | 2024-06-03 | ContractNo_2830 | 146d |
| ContractNo_2980 |  | Review & Approve 75% Design - Highway | 30d | 2024-06-04 | 2024-07-03 | ContractNo_2840 | 215d |
| ContractNo_2700 |  | Comment Resolution & Reissue 75% Design - Highway | 10d | 2024-07-05 | 2024-07-18 | ContractNo_2690, ContractNo_2980 | 145d |
| ContractNo_3570 |  | Submit 75% Design - Highway - REV1 (15 Days if required) | 0d | 2024-07-19 | 2024-07-19 | ContractNo_2700 | 145d |
| ContractNo_3580 |  | Review & Approve 75% Design - Highway - REV-1 (30 Days if required) | 0d | 2024-07-19 | 2024-07-19 | ContractNo_3570 | 215d |
|  | 3 | **100% Design - Highway** |  | 2024-07-19 | 2024-10-10 |  |  |
| ContractNo_2750 |  | Prepare 100% Design - Highway | 20d | 2024-07-19 | 2024-08-15 | ContractNo_3580 | 145d |
| ContractNo_2890 |  | Schedule & Conduct OTS Review - 100% Design - Highway | 2d | 2024-08-16 | 2024-08-19 | ContractNo_2750 | 145d |
| ContractNo_2900 |  | Finalize 100% Design - Highway | 2d | 2024-08-20 | 2024-08-21 | ContractNo_2890 | 145d |
| ContractNo_2910 |  | Formal QC Review 100% Design - Highway | 3d | 2024-08-22 | 2024-08-26 | ContractNo_2900 | 145d |
| ContractNo_2920 |  | Submit 100% Design - Highway | 1d | 2024-08-27 | 2024-08-27 | ContractNo_2910 | 145d |
| ContractNo_3000 |  | Review & Approve 100% Design - Highway (MassDOT) | 30d | 2024-08-28 | 2024-09-26 | ContractNo_2920 | 215d |
| ContractNo_2760 |  | Comment Resolution & Reissue 100% Design - Highway | 10d | 2024-09-27 | 2024-10-10 | ContractNo_2750, ContractNo_2920, ContractNo_3000 | 145d |
|  | 7 | **Final Design - Bridge & Highway** |  | 2024-10-11 | 2024-12-05 |  |  |
| ContractNo_2730 |  | Prepare "RFC" Final Design - Bridge & Highway | 9d | 2024-10-11 | 2024-10-24 | ContractNo_2720, ContractNo_2760 | 145d |
| ContractNo_2930 |  | Schedule & Conduct OTS Review - "RFC" Final Design - Bridge & Highway | 2d | 2024-10-25 | 2024-10-28 | ContractNo_2730 | 145d |
| ContractNo_2940 |  | Finalize "RFC" Final Design - Bridge & Highway | 2d | 2024-10-29 | 2024-10-30 | ContractNo_2930 | 145d |
| ContractNo_2950 |  | Formal QC Review "RFC" Final Design - Bridge & Highway | 3d | 2024-10-31 | 2024-11-04 | ContractNo_2940 | 145d |
| ContractNo_2960 |  | Submit "RFC" Final Design - Bridge & Highway | 1d | 2024-11-05 | 2024-11-05 | ContractNo_2950 | 145d |
| ContractNo_2740 |  | Review & Approve "RFC" Final Design - Bridge & Highway (MassDOT) | 30d | 2024-11-06 | 2024-12-05 | ContractNo_2730, ContractNo_2960 | 215d |
|  | 5 | **Early Action Construction Submittals** |  | 2023-07-24 | 2023-11-01 |  |  |
|  | 5 | **RTTM** |  | 2023-07-24 | 2023-11-01 |  |  |
| ContractNo_1470 |  | Prepare & Submit RTTM System | 20d | 2023-07-24 | 2023-08-18 | ContractNo_NTP SS | 45.6d |
| ContractNo_1540 |  | Review & Approve RTTM System | 30d | 2023-08-19 | 2023-09-17 | ContractNo_1470 | 67.6d |
| ContractNo_1480 |  | Comment Resolution & Reissue RTTM System | 10.4d | 2023-09-18 | 2023-10-02 | ContractNo_1470, ContractNo_1540 | 47.6d |
| ContractNo_1490 |  | Procure RTTM System | 30d | 2023-10-02 | 2023-11-01 | ContractNo_1480 | 69.6d |
|  | 1 | **Quality Management Plan (QMP)** |  | 2023-07-24 | 2023-09-17 |  |  |
| ContractNo_1040 |  | Prepare & Submit Quality Management Plan | 20d | 2023-07-24 | 2023-08-18 | ContractNo_NTP SS | 449d |
| ContractNo_1050 |  | Review & Approve Quality Management Plan | 30d | 2023-08-19 | 2023-09-17 | ContractNo_1040 | 660d |
|  | 7 | **Bathymetric Survey** |  | 2023-07-24 | 2023-08-15 |  |  |
| ContractNo_1360 |  | Schedule & Conduct Bathymetric Survey | 7d | 2023-07-24 | 2023-08-01 | ContractNo_NTP SS | 452d |
| ContractNo_1370 |  | Prepare & Submit Bathymetric Survey Report | 10d | 2023-08-02 | 2023-08-15 | ContractNo_1360 | 452d |
|  | 3 | **Final Hydraulic & Scour Analysis Report** |  | 2023-08-16 | 2023-09-13 |  |  |
| ContractNo_1380 |  | Prepare & Submit Final Hydraulic & Scour Analysis Report | 20d | 2023-08-16 | 2023-09-13 | ContractNo_1370 | 452d |
|  | 2 | **Temporary Trestle Design** |  | 2023-07-24 | 2023-10-19 |  |  |
| ContractNo_1390 |  | Prepare & Submit Temporary Trestle Design | 17d | 2023-07-24 | 2023-08-15 | ContractNo_NTP SS | 428.6d |
| ContractNo_1510 |  | Review & Approve Temporary Trestle | 30d | 2023-08-16 | 2023-09-14 | ContractNo_1390 | 628.6d |
| ContractNo_1400 |  | Comment Resolution & Reissue Temporary Trestle Design | 10.4d | 2023-09-15 | 2023-09-29 | ContractNo_1510 | 428.6d |
| ContractNo_1410 |  | Procure Temporary Trestle | 20d | 2023-09-29 | 2023-10-19 | ContractNo_1400 | 628.6d |
|  | 6 | **Support of Excavation Design** |  | 2023-07-24 | 2023-10-21 |  |  |
| ContractNo_1610 |  | Prepare & Submit Support of Excavation Design | 30d | 2023-07-24 | 2023-09-01 | ContractNo_NTP SS | 427d |
| ContractNo_1620 |  | Review & Approve Support of Excavation Design | 30d | 2023-09-02 | 2023-10-01 | ContractNo_1610 | 627d |
| ContractNo_1630 |  | Comment Resolution & Reissue Support of Excavation Design | 10d | 2023-10-02 | 2023-10-16 | ContractNo_1620 | 428d |
| ContractNo_1500 |  | Procure Support of Excavation | 5d | 2023-10-17 | 2023-10-21 | ContractNo_1630, ContractNo_1620 | 626d |
|  | 4 | **Existing Sewer Line Protection Plan** |  | 2023-07-24 | 2023-09-29 |  |  |
| ContractNo_1420 |  | Prepare & Submit Existing Sewer Line Protection Plan | 19d | 2023-07-24 | 2023-08-17 | ContractNo_NTP SS | 441d |
| ContractNo_1520 |  | Review & Approve Existing Sewer Line Protection Plan | 30d | 2023-08-18 | 2023-09-16 | ContractNo_1420 | 646d |
| ContractNo_1430 |  | Comment Resolution & Reissue Existing Sewer Line Protection Plan | 10d | 2023-09-01 | 2023-09-18 | ContractNo_1420, ContractNo_1520 FF | 440d |
| ContractNo_1460 |  | Conduct CCTV Inspection of Existing Sanitary Sewer & Submit Report | 10d | 2023-09-18 | 2023-09-29 | ContractNo_1430, ContractNo_1520 | 440d |
|  | 9 | **Stormwater Management Plan** |  | 2023-07-24 | 2023-09-19 |  |  |
| ContractNo_1440 |  | Prepare & Submit Stormwater Management Plan | 5d | 2023-07-24 | 2023-07-28 | ContractNo_NTP SS | 192d |
| ContractNo_1560 |  | Schedule & Conduct Over the Shoulder - Stormwater Management Plan | 5d | 2023-07-31 | 2023-08-04 | ContractNo_1440 | 192d |
| ContractNo_1530 |  | Review & Approve Stormwater Management Plan | 30d | 2023-08-05 | 2023-09-03 | ContractNo_1440, ContractNo_1560 | 281d |
| ContractNo_1450 |  | Comment Resolution & Reissue Stormwater Management Plan | 10.4d | 2023-09-05 | 2023-09-19 | ContractNo_1440, ContractNo_1530 | 448.6d |
|  | 12 | **Geotechnical Instrumentation & Monitoring Plan** |  | 2023-07-24 | 2023-09-29 |  |  |
| ContractNo_1580 |  | Prepare & Submit Geotechnical Instrumentation & Monitoring Plan | 20d | 2023-07-24 | 2023-08-18 | ContractNo_NTP SS | 440d |
| ContractNo_1590 |  | Review & Approve Geotechnical Instrumentation & Monitoring Plan | 30d | 2023-08-19 | 2023-09-17 | ContractNo_1580 | 645d |
| ContractNo_1600 |  | Install Geotechnical & Monitoring Instrumentation | 10d | 2023-09-18 | 2023-09-29 | ContractNo_1590 | 440d |
|  | 6 | **Quality Control Plans** |  | 2023-07-24 | 2023-10-18 |  |  |
|  | 1 | **Drilled Shaft Quality Control Plan** |  | 2023-07-24 | 2023-10-18 |  |  |
| ContractNo_2400 |  | Prepare & Submit Drilled Shaft Quality Control Plan | 40d | 2023-07-24 | 2023-09-18 | ContractNo_NTP SS | 429d |
| ContractNo_2410 |  | Review & Approve Drilled Shaft Quality Control Plan | 30d | 2023-09-19 | 2023-10-18 | ContractNo_2400 | 629d |
|  | 2 | **Deck Membrane Waterproofing** |  | 2023-07-24 | 2023-10-18 |  |  |
| ContractNo_2420 |  | Prepare & Submit Deck Membrane Waterproofing Quality Control Plan | 40d | 2023-07-24 | 2023-09-18 | ContractNo_NTP SS | 429d |
| ContractNo_2430 |  | Review & Approve Deck Membrane Waterproofing Quality Control Plan | 30d | 2023-09-19 | 2023-10-18 | ContractNo_2420 | 629d |
|  | 3 | **Earthwork** |  | 2023-07-24 | 2023-10-18 |  |  |
| ContractNo_2440 |  | Prepare & Submit Earthwork Quality Control Plan | 40d | 2023-07-24 | 2023-09-18 | ContractNo_NTP SS | 429d |
| ContractNo_2450 |  | Review & Approve Earthwork Quality Control Plan | 30d | 2023-09-19 | 2023-10-18 | ContractNo_2440 | 629d |
|  | 4 | **HMA Pavement** |  | 2023-07-24 | 2023-10-18 |  |  |
| ContractNo_2460 |  | Prepare & Submit HMA Pavement Quality Control Plan | 40d | 2023-07-24 | 2023-09-18 | ContractNo_NTP SS | 429d |

| ID | WBS | Task | Duration | Start | Finish | Predecessors | Total float |
| --- | --- | --- | --- | --- | --- | --- | --- |
| ContractNo_2470 |  | Review & Approve HMA Pavement Quality Control Plan | 30d | 2023-09-19 | 2023-10-18 | ContractNo_2460 | 629d |
|  | 5 | **Portland Cement Concrete - Cast in Place Elements** |  | 2023-07-24 | 2023-10-18 |  |  |
| ContractNo_2480 |  | Prepare & Submit Portland Cement Concrete - Cast in Place Elements Quality Control Plan | 40d | 2023-07-24 | 2023-09-18 | ContractNo_NTP SS | 429d |
| ContractNo_2490 |  | Review & Approve Portland Cement Concrete - Cast in Place Elements Quality Control Plan | 30d | 2023-09-19 | 2023-10-18 | ContractNo_2480 | 629d |
|  | 6 | **Structural Steel Element** |  | 2023-07-24 | 2023-10-18 |  |  |
| ContractNo_2500 |  | Prepare & Submit Structural Steel Element Quality Control Plan | 40d | 2023-07-24 | 2023-09-18 | ContractNo_NTP SS | 429d |
| ContractNo_2510 |  | Review & Approve Structural Steel Element Quality Control Plan | 30d | 2023-09-19 | 2023-10-18 | ContractNo_2500 | 629d |
|  | 7 | **Construction Submittals** |  | 2023-07-24 | 2024-03-15 |  |  |
|  | 2 | **Traffic Management Plan (TTCP)** |  | 2023-07-24 | 2023-11-02 |  |  |
| ContractNo_1900 |  | Prepare Traffic Management Plan (Stage 1) | 35d | 2023-07-24 | 2023-09-11 | ContractNo_NTP SS | 46d |
| ContractNo_1910 |  | Schedule & Conduct OTS Review - Traffic Management Plan (Stage 1) | 2d | 2023-09-12 | 2023-09-13 | ContractNo_1900 | 46d |
| ContractNo_1810 |  | Submit Traffic Management Plan (Stage 1) | 4d | 2023-09-14 | 2023-09-19 | ContractNo_1910 | 46d |
| ContractNo_2030 |  | Review & Approve Traffic Management Plan (Stage 1) | 30d | 2023-09-20 | 2023-10-19 | ContractNo_1810 | 68d |
| ContractNo_1820 |  | Comment Resolution & Reissue Traffic Management Plan | 10d | 2023-10-20 | 2023-11-02 | ContractNo_1810, ContractNo_2030 | 46d |
|  | 11 | **Existing Bridge Monitoring Plan** |  | 2023-07-24 | 2023-08-18 |  |  |
| ContractNo_2210 |  | Prepare & Submit Existing Bridge Monitoring Plan | 20d | 2023-07-24 | 2023-08-18 | ContractNo_NTP SS | 214d |
|  | 12 | **Dewatering Plan** |  | 2023-07-24 | 2023-11-01 |  |  |
| ContractNo_2380 |  | Prepare & Submit Dewatering Plan | 50d | 2023-07-24 | 2023-10-02 | ContractNo_NTP SS | 419d |
| ContractNo_2390 |  | Review & Approve Dewatering Plan | 30d | 2023-10-03 | 2023-11-01 | ContractNo_2380 | 615d |
|  | 6 | **Demolition Plan - NB** |  | 2023-07-24 | 2023-12-29 |  |  |
| ContractNo_2170 |  | Prepare & Submit Demolition Plan | 90d | 2023-07-24 | 2023-11-29 | ContractNo_NTP SS | 123d |
| ContractNo_2180 |  | Review & Approve Demolition Plan | 30d | 2023-11-30 | 2023-12-29 | ContractNo_2170 | 181d |
|  | 13 | **Drilled Shaft Installation/Testing Procedure** |  | 2023-07-24 | 2023-11-30 |  |  |
| ContractNo_2240 |  | Prepare & Submit Drilled Shaft Installation/Testing Procedure | 70d | 2023-07-24 | 2023-10-31 | ContractNo_NTP SS | 399d |
| ContractNo_2250 |  | Review & Approve Drilled Shaft Installation/Testing Procedure | 30d | 2023-11-01 | 2023-11-30 | ContractNo_2240 | 586d |
|  | 5 | **Abutment Pile Intsallation Plan** |  | 2023-07-24 | 2023-10-18 |  |  |
| ContractNo_2260 |  | Prepare & Submit Abutment Pile Installation Plan | 40d | 2023-07-24 | 2023-09-18 | ContractNo_NTP SS | 429d |
| ContractNo_2270 |  | Review & Approve Abutment Pile Installation Plan | 30d | 2023-09-19 | 2023-10-18 | ContractNo_2260 | 629d |
|  | 7 | **Erection Plan - Stage 1** |  | 2023-07-24 | 2023-11-16 |  |  |
| ContractNo_2190 |  | Prepare & Submit Erection Plan - Stage 1 | 60d | 2023-07-24 | 2023-10-17 | ContractNo_NTP SS | 175d |
| ContractNo_2200 |  | Review & Approve Erection Plan - Stage 1 | 30d | 2023-10-18 | 2023-11-16 | ContractNo_2190 | 257d |
|  | 3 | **Erection Plan - Stage 2** |  | 2023-11-17 | 2024-03-15 |  |  |
| ContractNo_2280 |  | Prepare & Submit Erection Plan - Stage 2 | 60d | 2023-11-17 | 2024-02-14 | ContractNo_2200, ContractNo_NTP SS | 327d |
| ContractNo_2290 |  | Review & Approve Erection Plan - Stage 2 | 30d | 2024-02-15 | 2024-03-15 | ContractNo_2280 | 480d |
|  | 4 | **Erection Plan - Stage 3** |  | 2023-07-24 | 2023-11-16 |  |  |
| ContractNo_2300 |  | Prepare & Submit Erection Plan - Stage 3 | 60d | 2023-07-24 | 2023-10-17 | ContractNo_NTP SS | 409d |
| ContractNo_2310 |  | Review & Approve Erection Plan - Stage 3 | 30d | 2023-10-18 | 2023-11-16 | ContractNo_2300 | 600d |
|  | 10 | **Deck Placement Plan** |  | 2023-07-24 | 2023-12-29 |  |  |
| ContractNo_2320 |  | Prepare & Submit Deck Placement Plan | 90d | 2023-07-24 | 2023-11-29 | ContractNo_NTP SS | 379d |
| ContractNo_2330 |  | Review & Approve Deck Placement Plan | 30d | 2023-11-30 | 2023-12-29 | ContractNo_2320 | 557d |
|  | 8 | **Solid Pier Wall Construction Plan** |  | 2023-07-24 | 2023-11-16 |  |  |
| ContractNo_2340 |  | Prepare & Submit Solid Pier Wall Construction Plan | 60d | 2023-07-24 | 2023-10-17 | ContractNo_NTP SS | 409d |
| ContractNo_2350 |  | Review & Approve Solid Pier Wall Construction Plan | 30d | 2023-10-18 | 2023-11-16 | ContractNo_2340 | 600d |
|  | 9 | **Formwork Plan** |  | 2023-07-24 | 2023-11-16 |  |  |
| ContractNo_2360 |  | Prepare & Submit Formwork Plan | 60d | 2023-07-24 | 2023-10-17 | ContractNo_NTP SS | 409d |
| ContractNo_2370 |  | Review & Approve Formwork Plan | 30d | 2023-10-18 | 2023-11-16 | ContractNo_2360 | 600d |
|  | 1 | **Subcontractor Approvals** |  |  |  |  |  |
|  | 1 | **Licensed Site Professional** |  |  |  |  |  |
|  | 2 | **Structure Cleaning Subcontractor** |  |  |  |  |  |
|  | 3 | **Electrical Subcontractor** |  |  |  |  |  |
|  | 4 | **Bridge Demolition Subcontractor** |  |  |  |  |  |
|  | 8 | **Shop Drawings and Procurements** |  | 2023-07-24 | 2024-03-24 |  |  |
|  | 16 | **Superstructure Rebar Design** |  | 2023-07-24 | 2023-10-25 |  |  |
| ContractNo_3040 |  | Prepare & Submit Early Release Superstructure Rebar Design | 45d | 2023-07-24 | 2023-09-25 | ContractNo_NTP SS | 333d |
| ContractNo_3050 |  | Review & Approve Early Release Superstructure Rebar Design | 30d | 2023-09-26 | 2023-10-25 | ContractNo_3040 | 490d |
|  | 9 | **Abutment Rebar** |  | 2023-07-24 | 2023-10-17 |  |  |
| ContractNo_3010 |  | Prepare & Submit Substructure Rebar Shop Drawings | 20d | 2023-07-24 | 2023-08-18 | ContractNo_NTP SS | 430d |
| ContractNo_3020 |  | Review & Approve Substructure Rebar Shop Drawings | 30d | 2023-08-19 | 2023-09-17 | ContractNo_3010 | 630d |
| ContractNo_3030 |  | Procure Substructure Rebar | 30d | 2023-09-18 | 2023-10-17 | ContractNo_3020 | 630d |
|  | 14 | **Drilled Shaft Rebar** |  | 2023-07-24 | 2023-10-17 |  |  |
| ContractNo_3510 |  | Prepare & Submit Drilled Shaft Rebar Shop Drawings | 20d | 2023-07-24 | 2023-08-18 | ContractNo_NTP SS | 430d |
| ContractNo_3520 |  | Review & Approve Drilled Shaft Rebar Shop Drawings | 30d | 2023-08-19 | 2023-09-17 | ContractNo_3510 | 630d |
| ContractNo_3530 |  | Procure Drilled Shaft Rebar | 30d | 2023-09-18 | 2023-10-17 | ContractNo_3520 | 630d |
|  | 15 | **Pier Substructure Rebar** |  | 2023-07-24 | 2023-11-01 |  |  |
| ContractNo_3540 |  | Prepare & Submit Pier Substructure Rebar Shop Drawings | 20d | 2023-07-24 | 2023-08-18 | ContractNo_NTP SS | 419d |
| ContractNo_3550 |  | Review & Approve Pier Substructure Rebar Shop Drawings | 30d | 2023-08-19 | 2023-09-17 | ContractNo_3540 | 615d |
| ContractNo_3560 |  | Procure Pier Substructure Rebar | 45d | 2023-09-18 | 2023-11-01 | ContractNo_3550 | 615d |
|  | 3 | **Stay in Place Formwork** |  | 2023-07-24 | 2023-11-16 |  |  |
| ContractNo_3330 |  | Prepare & Submit Stay in Place Formwork | 20d | 2023-07-24 | 2023-08-18 | ContractNo_NTP SS | 409d |
| ContractNo_3340 |  | Review & Approve Stay in Place Formwork | 30d | 2023-08-19 | 2023-09-17 | ContractNo_3330 | 600d |

| ID | WBS | Task | Duration | Start | Finish | Predecessors | Total float |
| --- | --- | --- | --- | --- | --- | --- | --- |
| ContractNo_3350 |  | Procure Stay in Place Formwork | 60d | 2023-09-18 | 2023-11-16 | ContractNo_3340 | 600d |
|  | 7 | **Solid Pier Wall (Pier Bases) Design & Shop Drawings** |  | 2023-07-24 | 2024-03-24 |  |  |
| ContractNo_3130 |  | Prepare & Submit - Solid Pier Wall (Pier Bases) Design | 60d | 2023-07-24 | 2023-10-17 | ContractNo_NTP SS | 322d |
| ContractNo_3140 |  | Review & Approve - Solid Pier Wall (Pier Bases) Design | 30d | 2023-10-18 | 2023-11-16 | ContractNo_3130 | 472d |
| ContractNo_3070 |  | Prepare & Submit - Solid Pier Wall (Pier Bases) Shop Drawings | 20d | 2023-11-17 | 2023-12-15 | ContractNo_3140 | 319d |
| ContractNo_3080 |  | Review & Approve Solid Pier Wall Shop Drawings | 30d | 2023-12-16 | 2024-01-14 | ContractNo_3070 | 471d |
| ContractNo_3090 |  | Procure Solid Pier Wall Material | 70d | 2024-01-15 | 2024-03-24 | ContractNo_3080 | 471d |
|  | 5 | **Drainage Structures** |  | 2023-07-24 | 2023-10-12 |  |  |
| ContractNo_3100 |  | Prepare & Submit Drainage Structures | 20d | 2023-07-24 | 2023-08-18 | ContractNo_NTP SS | 433d |
| ContractNo_3110 |  | Review & Approve Drainage Structures | 30d | 2023-08-19 | 2023-09-17 | ContractNo_3100 | 635d |
| ContractNo_3120 |  | Procure Drainage Structures | 25d | 2023-09-18 | 2023-10-12 | ContractNo_3110 | 635d |
|  | 1 | **TL-5 Pier Protection Barrier** |  | 2023-07-24 | 2023-10-22 |  |  |
| ContractNo_3160 |  | Prepare & Submit TL-5 Pier Protection Barrier | 20d | 2023-07-24 | 2023-08-18 | ContractNo_NTP SS | 425d |
| ContractNo_3170 |  | Review & Approve TL-5 Pier Protection Barrier | 30d | 2023-08-19 | 2023-09-17 | ContractNo_3160 | 625d |
| ContractNo_3180 |  | Procure TL-5 Pier Protection Barrier | 35d | 2023-09-18 | 2023-10-22 | ContractNo_3170 | 625d |
|  | 12 | **Bridge Bearings** |  | 2023-07-24 | 2023-11-30 |  |  |
| ContractNo_3220 |  | Prepare & Submit Bridge Bearings Shop Drawings | 30d | 2023-07-24 | 2023-09-01 | ContractNo_NTP SS | 399d |
| ContractNo_3230 |  | Review & Approve Bridge Bearings Shop Drawings | 30d | 2023-09-02 | 2023-10-01 | ContractNo_3220 | 586d |
| ContractNo_3190 |  | Procure Bridge Bearings | 60d | 2023-10-02 | 2023-11-30 | ContractNo_3230 | 586d |
|  | 4 | **Superstructure Rebar** |  | 2023-10-26 | 2024-03-06 |  |  |
| ContractNo_3360 |  | Prepare & Submit Superstructure Rebar Shop Drawings | 30d | 2023-10-26 | 2023-12-07 | ContractNo_3050, ContractNo_NTP SS | 333d |
| ContractNo_3370 |  | Review & Approve Superstructure Rebar Shop Drawings | 30d | 2023-12-08 | 2024-01-06 | ContractNo_3360 | 489d |
| ContractNo_3060 |  | Procure Superstructure Rebar | 60d | 2024-01-07 | 2024-03-06 | ContractNo_3370 | 489d |
|  | 6 | **Bridge Scuppers** |  | 2023-07-24 | 2023-11-30 |  |  |
| ContractNo_3380 |  | Prepare & Submit Bridge Scupper Shop Drawings | 30d | 2023-07-24 | 2023-09-01 | ContractNo_NTP SS | 399d |
| ContractNo_3390 |  | Review & Approve Bridge Scupper Shop Drawings | 30d | 2023-09-02 | 2023-10-01 | ContractNo_3380 | 586d |
| ContractNo_3200 |  | Procure/Fabricate Bridge Scuppers | 60d | 2023-10-02 | 2023-11-30 | ContractNo_3390 | 586d |
|  | 8 | **Bridge Joint** |  | 2023-07-24 | 2023-11-30 |  |  |
| ContractNo_3400 |  | Prepare & Submit Bridge Shop Drawings | 30d | 2023-07-24 | 2023-09-01 | ContractNo_NTP SS | 399d |
| ContractNo_3410 |  | Review & Approve Bridge Joint Design | 30d | 2023-09-02 | 2023-10-01 | ContractNo_3400 | 586d |
| ContractNo_3210 |  | Procure/Fabricate Bridge Joint | 60d | 2023-10-02 | 2023-11-30 | ContractNo_3410 | 586d |
|  | 9 | **Early Action Permit Plan Changes** |  | 2023-07-24 | 2023-10-30 |  |  |
|  | 1 | **National Marine Fishery Service (NMFS)** |  | 2023-07-24 | 2023-10-29 |  |  |
| ContractNo_1300 |  | Prepare & Submit Revised Section 7 Letter | 25d | 2023-07-24 | 2023-08-25 | ContractNo_NTP SS | 177d |
| ContractNo_1310 |  | Review & Approve Revised Section 7 Letter | 30d | 2023-08-26 | 2023-09-24 | ContractNo_1300 | 260d |
| ContractNo_1330 |  | Comment Resolution & Reissue Revised Section 7 Letter | 5d | 2023-09-25 | 2023-09-29 | ContractNo_1310 | 178d |
| ContractNo_1320 |  | NMFS - Review & Approve Revised Section 7 Letter | 30d | 2023-09-30 | 2023-10-29 | ContractNo_1310, ContractNo_1330 | 617d |
|  | 11 | **Water Quality Certification Permit Plan Changes** |  | 2023-07-24 | 2023-10-30 |  |  |
| ContractNo_1220 |  | Prepare & Submit WQC Permit Plan Changes | 20d | 2023-07-24 | 2023-08-18 | ContractNo_NTP SS | 425d |
| ContractNo_1240 |  | Review & Approve WQC Permit Plan Changes | 30d | 2023-08-19 | 2023-09-17 | ContractNo_1220 | 623d |
| ContractNo_1280 |  | Comment Resolution & Reissue WQC Permit Plan Changes | 5d | 2023-09-18 | 2023-09-22 | ContractNo_1240 | 425d |
| ContractNo_1260 |  | MassDEP - Review & Approve WQC Permit Plan Changes | 30d | 2023-09-22 | 2023-10-22 | ContractNo_1240, ContractNo_1280 | 624.67d |
| ContractNo_1340 |  | MassDEP - Issue WQC Permit Plan Changes | 1d | 2023-10-30 | 2023-10-30 | ContractNo_1260, ContractNo_1320 | 420d |
|  | 12 | **Army Corp of Engineers Permit Plan Changes** |  | 2023-07-24 | 2023-10-30 |  |  |
| ContractNo_1230 |  | Prepare & Submit ACOE Permit Plan Changes | 17d | 2023-07-24 | 2023-08-15 | ContractNo_NTP SS | 428d |
| ContractNo_1250 |  | Review & Approve ACOE Permit Plan Changes | 30d | 2023-08-16 | 2023-09-14 | ContractNo_1230 | 626d |
| ContractNo_1290 |  | Comment Resolution & Reissue ACOE Permit Plan Changes | 5d | 2023-09-15 | 2023-09-21 | ContractNo_1250 | 426d |
| ContractNo_1270 |  | ACOE - Review & Approve ACOE Permit Plan Changes | 30d | 2023-09-21 | 2023-10-21 | ContractNo_1250, ContractNo_1290 | 625.67d |
| ContractNo_1350 |  | ACOE - Issue ACOE Permit Plan Changes | 1d | 2023-10-30 | 2023-10-30 | ContractNo_1270, ContractNo_1320 | 420d |
|  | Uti | **Utility** |  | 2023-08-02 | 2024-04-10 |  |  |
|  | URP | **Utility Relocation & Coordination Plan** |  | 2023-08-02 | 2023-08-22 |  |  |
| ContractNo_P250 |  | Prepare & Submit - Early Utiltiy Relocation Request\Coordination Plan | 14d | 2023-08-02 | 2023-08-15 | ContractNo_NTP SS, ContractNo_PCM2 SS | 125d |
| ContractNo_P260 |  | Review & Approve - Early Utiltiy Relocation Request\Coordination Plan | 7d | 2023-08-16 | 2023-08-22 | ContractNo_P250 | 125d |
|  | Not | **Utility Notifications & Meetings** |  | 2023-08-23 | 2023-09-21 |  |  |
| ContractNo_U100 |  | Coordinate/Mobilization Period - Relocation w/ Utility Company - [insert Utility 1 Name] | 30d | 2023-08-23 | 2023-09-21 | ContractNo_P260 | 125d |
| ContractNo_U350 |  | Coordinate/Mobilization Period - Relocation w/ Utility Company - [insert Utility 2 Name] | 30d | 2023-08-23 | 2023-09-21 | ContractNo_P260 | 161d |
| ContractNo_U360 |  | Coordinate/Mobilization Period - Relocation w/ Utility Company - [insert Utility 3 Name] | 30d | 2023-08-23 | 2023-09-21 | ContractNo_P260 | 196d |
| ContractNo_U370 |  | Coordinate/Mobilization Period - Relocation w/ Utility Company - [insert Utility 4 Name] | 30d | 2023-08-23 | 2023-09-21 | ContractNo_P260 | 234d |
|  | Rel | **Utility Relocation** |  | 2023-11-15 | 2024-04-10 |  |  |
|  | 1 | **Utility 1 PUC Tasks** |  | 2023-11-15 | 2023-12-21 |  |  |
| ContractNo_U340 |  | Utility 1 Task 1: Copy Activity Name from PUC Form | 20d | 2023-11-15 | 2023-12-14 | ContractNo_U100, ContractNo_C900 | 46.6d |
| ContractNo_U120 |  | Utility 1 Task 2: Copy Activity Name from PUC Form | 5d | 2023-12-14 | 2023-12-21 | ContractNo_U340 | 46.6d |
|  | 2 | **Utility 2 PUC Tasks** |  | 2023-12-21 | 2024-01-30 |  |  |
| ContractNo_U380 |  | Utility 2 Task 1: Copy Activity Name from PUC Form | 20d | 2023-12-21 | 2024-01-23 | ContractNo_U120, ContractNo_U350 | 46.6d |
| ContractNo_U390 |  | Utility 2 Task 2: Copy Activity Name from PUC Form | 5d | 2024-01-23 | 2024-01-30 | ContractNo_U380 | 46.6d |
|  | 3 | **Utility 3 PUC Tasks** |  | 2024-01-30 | 2024-03-06 |  |  |
| ContractNo_U400 |  | Utility 3 Task 1: Copy Activity Name from PUC Form | 20d | 2024-01-30 | 2024-02-28 | ContractNo_U390, ContractNo_U360 | 46.6d |
| ContractNo_U410 |  | Utility 3 Task 2: Copy Activity Name from PUC Form | 5d | 2024-02-28 | 2024-03-06 | ContractNo_U400 | 46.6d |
|  | 4 | **Utility 4 PUC Tasks** |  | 2024-03-06 | 2024-04-10 |  |  |
| ContractNo_U420 |  | Utility 4 Task 1: Copy Activity Name from PUC Form | 20d | 2024-03-06 | 2024-04-03 | ContractNo_U410, ContractNo_U370 | 46.6d |

| ID | WBS | Task | Duration | Start | Finish | Predecessors | Total float |
| --- | --- | --- | --- | --- | --- | --- | --- |
| ContractNo_U430 |  | Utility 4 Task 2: Copy Activity Name from PUC Form | 5d | 2024-04-03 | 2024-04-10 | ContractNo_U420 | 46.6d |
|  | ServConn | **Utility Service Connections** |  | 2023-08-02 | 2023-09-13 |  |  |
| ContractNo_U440 |  | Design-Builder Request WO# for Service Connection @ Location XXX (If Required) | 5d | 2023-08-02 | 2023-08-08 | ContractNo_PCM2 SS | 93d |
| ContractNo_U450 |  | Utility Assigns WO# for Service Connection @ Location XXX (If Required) | 5d | 2023-08-09 | 2023-08-15 | ContractNo_U440 | 93d |
| ContractNo_U460 |  | Utility Completes Design and Requests Payment for WO# @ Location XXX (If Required) | 20d | 2023-08-15 | 2023-09-04 | ContractNo_U450 | 135.67d |
| ContractNo_U470 |  | Design-Builder installs UG conduit @ Location XXX (If Required) | 5d | 2023-09-05 | 2023-09-11 | ContractNo_U460 | 92d |
| ContractNo_U480 |  | Utility Performs Service Connection @ Location XXX (If Required) | 2d | 2023-09-12 | 2023-09-13 | ContractNo_U470 | 401d |
|  | Con | **Construction** |  | 2023-01-03 | 2025-05-01 |  |  |
|  | Gene | **General** |  | 2023-07-24 | 2023-08-02 |  |  |
| ContractNo_PCM1 |  | Schedule Pre-Construction Meeting/Schedule Planning Session | 7d | 2023-07-24 | 2023-08-01 | ContractNo_NTP SS | 86d |
| ContractNo_PCM2 |  | Conduct Pre-Construction Meeting/Schedule Planning Session | 0d | 2023-08-02 | 2023-08-02 | ContractNo_PCM1 | 86d |
|  | Mobi | **Start-up** |  | 2023-01-03 | 2023-11-15 |  |  |
| ContractNo_C910 |  | MassDOT Baseline Survey / Layout of Utility Pole Locations | 20d | 2023-01-03 | 2023-01-31 |  | 240d |
| ContractNo_C070 |  | Design-Builder Mobilize | 20d | 2023-08-02 | 2023-08-29 | ContractNo_NTP SS, ContractNo_PCM2 SS | 90d |
| ContractNo_C100 |  | Establish Engineer's Field Office | 20d | 2023-08-02 | 2023-08-29 | ContractNo_C070 SS, ContractNo_PCM2 SS | 90d |
| ContractNo_C370 |  | Install Traffic Devices, RTTM System, Barriers, Signage | 5d | 2023-11-01 | 2023-11-08 | ContractNo_C100, ContractNo_2030, ContractNo_1490 | 46.6d |
| ContractNo_C080 |  | Install SWPPP Systems | 5d | 2023-11-08 | 2023-11-15 | ContractNo_C070, ContractNo_C370, ContractNo_1530 | 146.6d |
| ContractNo_C900 |  | Design-Builder Performs Utility Enabling Work (If Required) | 5d | 2023-11-08 | 2023-11-15 | ContractNo_C910, ContractNo_C370, ContractNo_U470 SS | 46.6d |
|  | Ph1 | **Stage 1** |  | 2024-04-10 | 2024-09-11 |  |  |
|  | StpA | **Step A** |  | 2024-04-10 | 2024-07-15 |  |  |
| ContractNo_C465 |  | Install Temporary Shielding - [Location] | 7d | 2024-04-10 | 2024-04-22 | ContractNo_C080, ContractNo_U430 | 46.6d |
| ContractNo_C480 |  | Environmental Protection of Box Turtles | 5d | 2024-06-03 | 2024-06-07 | ContractNo_1330 | 11d |
| ContractNo_C475 |  | Demo Existing Superstructure - [Location] | 4d | 2024-06-10 | 2024-06-13 | ContractNo_C080, ContractNo_C465, ContractNo_2180, ContractNo_2210, ContractNo_C480 | 13d |
| ContractNo_C485 |  | Install Water Control Measures - [Location] | 6d | 2024-06-10 | 2024-06-17 | ContractNo_C480, ContractNo_1530, ContractNo_2530 | 11d |
| ContractNo_C490 |  | Excavate Abutments & Surrounding Area - [Location] | 8d | 2024-06-18 | 2024-06-28 | ContractNo_C475, ContractNo_C485 | 11d |
| ContractNo_C505 |  | Demo Existing Substructure - [Location] | 6d | 2024-07-01 | 2024-07-09 | ContractNo_C475, ContractNo_C485, ContractNo_C490, ContractNo_AR01 | 11d |
| ContractNo_C515 |  | Set & Grout Precast Abutments - [Location] (NOTE: Ensure Grout Cure Period is accounted for) | 4d | 2024-07-10 | 2024-07-15 | ContractNo_C505 | 11d |
|  | StpB | **Step B** |  | 2024-07-16 | 2024-09-11 |  |  |
| ContractNo_C525 |  | Install Steel Beams - [Location] | 6d | 2024-07-16 | 2024-07-23 | ContractNo_C515, ContractNo_2200, ContractNo_1730 | 11d |
| ContractNo_C535 |  | Install Precast Decks - [Location] | 3d | 2024-07-24 | 2024-07-26 | ContractNo_C525 | 11d |
| ContractNo_C920 |  | Postension Precast Decks - [Location] | 1d | 2024-07-29 | 2024-07-29 | ContractNo_C535 | 11d |
| ContractNo_C545 |  | Grout Precast Decks - [Location] (NOTE: Ensure Grout Cure Period is accounted for) | 3d | 2024-07-30 | 2024-08-01 | ContractNo_C535, ContractNo_C920 | 11d |
| ContractNo_C555 |  | F/R/Pour Sidewalk Placement 1 - [Location] | 4d | 2024-08-02 | 2024-08-07 | ContractNo_C545 | 11d |
| ContractNo_C930 |  | 72 Hour Placement Cure Period for Sidewalks - [Location] | 3d | 2024-08-07 | 2024-08-10 | ContractNo_C555 | 15.67d |
| ContractNo_C940 |  | Sidewalk Placement 2 - [Location] | 2d | 2024-08-12 | 2024-08-13 | ContractNo_C930 | 10d |
| ContractNo_C950 |  | Full Cure Period for Sidewalks - [Location] | 14d | 2024-08-13 | 2024-08-27 | ContractNo_C940 | 14.67d |
| ContractNo_C575 |  | Install waterproofing - [Location] | 3d | 2024-08-28 | 2024-08-30 | ContractNo_C555, ContractNo_C950 | 9d |
| ContractNo_C580 |  | Place Protective Course Pavement - [Location] | 1d | 2024-09-03 | 2024-09-03 | ContractNo_C575, ContractNo_C950 | 9d |
| ContractNo_C565 |  | Install Railings - [Location] | 4d | 2024-09-04 | 2024-09-09 | ContractNo_C555, ContractNo_C950, ContractNo_C580 | 9d |
| ContractNo_C590 |  | Install Pavement Markers, Sign and Stripe - [Location] | 2d | 2024-09-04 | 2024-09-05 | ContractNo_C580 | 11d |
| ContractNo_C585 |  | Complete Phase 1 - [Location] | 0d | 2024-09-09 | 2024-09-09 | ContractNo_C590, ContractNo_C565 | 9d |
| ContractNo_C595 |  | Set Jersey Barriers & Signage - [Location] | 2d | 2024-09-10 | 2024-09-11 | ContractNo_C590, ContractNo_C585 | 88d |
|  | StpC | **Step C** |  |  |  |  |  |
|  | StpD | **Step D** |  |  |  |  |  |
|  | Ph2 | **Stage 2** |  | 2024-09-10 | 2025-05-01 |  |  |
|  | StpA | **Step A** |  | 2024-09-10 | 2024-10-04 |  |  |
| ContractNo_C755 |  | Install Water Control Measures - [Location] | 6d | 2024-09-10 | 2024-09-17 | ContractNo_C585 | 9d |
| ContractNo_C750 |  | Traffic Switch from Phase I - [Location] | 2d | 2024-09-12 | 2024-09-13 | ContractNo_C595, ContractNo_C585 | 88d |
| ContractNo_C765 |  | Install Temporary Shielding - [Location] | 5d | 2024-09-16 | 2024-09-20 | ContractNo_C750 | 88d |
| ContractNo_C790 |  | Excavate Abutments & Surrounding Area - [Location] | 8d | 2024-09-18 | 2024-09-27 | ContractNo_C755 | 101d |
| ContractNo_C805 |  | Demo Existing Substructure - [Location] | 6d | 2024-09-23 | 2024-09-30 | ContractNo_C755, ContractNo_C765 | 88d |
| ContractNo_C815 |  | Set & Grout Precast Abutments - [Location] (NOTE: Ensure Grout Cure Period is accounted for) | 4d | 2024-10-01 | 2024-10-04 | ContractNo_C805 | 88d |
|  | StpB | **Step B** |  | 2024-10-07 | 2025-04-23 |  |  |
| ContractNo_C825 |  | Install Steel Beams - [Location] | 6d | 2024-10-07 | 2024-10-15 | ContractNo_C815 | 88d |
| ContractNo_C835 |  | Install Precast Decks - [Location] | 4d | 2024-10-16 | 2024-10-21 | ContractNo_C825 | 88d |
| ContractNo_C960 |  | Postension Precast Decks - [Location] | 1d | 2024-10-22 | 2024-10-22 | ContractNo_C835 | 88d |
| ContractNo_C845 |  | Grout Precast Decks - [Location] | 3d | 2024-10-23 | 2024-10-25 | ContractNo_C835, ContractNo_C960 | 88d |
| ContractNo_C855 |  | F/R/Pour Sidewalk Placement 1 - [Location] | 2d | 2024-10-28 | 2024-10-29 | ContractNo_C845 | 88d |
| ContractNo_C970 |  | 72 Hour Placement Cure Period for Sidewalks - [Location] | 3d | 2024-10-29 | 2024-11-01 | ContractNo_C855 | 132.67d |
| ContractNo_C980 |  | Sidewalk Placement 2 - [Location] | 2d | 2024-11-04 | 2024-11-05 | ContractNo_C970 | 88d |
| ContractNo_C990 |  | Full Cure Period for Sidewalks - [Location] | 14d | 2024-11-05 | 2024-11-19 | ContractNo_C980 | 132.67d |
| ContractNo_C875 |  | Install waterproofing - [Location] | 3d | 2025-04-01 | 2025-04-03 | ContractNo_C855, ContractNo_C990 | 0d |
| ContractNo_C1000 |  | Place Protective Course Pavement - [Location] | 3d | 2025-04-04 | 2025-04-08 | ContractNo_C875 | 0d |
| ContractNo_C865 |  | Install Railings - [Location] | 4d | 2025-04-09 | 2025-04-14 | ContractNo_C855, ContractNo_C1000 | 0d |
| ContractNo_C880 |  | Place Base & Top Pavement - [Location] | 4d | 2025-04-15 | 2025-04-18 | ContractNo_C875, ContractNo_C320, ContractNo_C865 | 0d |
| ContractNo_C890 |  | Install Pavement Markers, Sign and Stripe - [Location] | 2d | 2025-04-22 | 2025-04-23 | ContractNo_C880 | 0d |
| ContractNo_C885 |  | Complete Phase 2 - [Location] | 0d | 2025-04-23 | 2025-04-23 | ContractNo_C890, ContractNo_C865 | 0d |
|  | StpC | **Step C** |  | 2024-09-30 | 2025-05-01 |  |  |
| ContractNo_C190 |  | Approach Work - Raise Grades - [Location] | 16d | 2024-09-30 | 2024-10-22 | ContractNo_C790 | 101d |
| ContractNo_C200 |  | Repair Underground Drainage Structure - [Location] | 5d | 2024-10-23 | 2024-10-29 | ContractNo_C190, ContractNo_U430 | 101d |

| ID | WBS | Task | Duration | Start | Finish | Predecessors | Total float |
| --- | --- | --- | --- | --- | --- | --- | --- |
| ContractNo_C320 |  | Backfill & Grade - [Location] | 12d | 2024-10-30 | 2024-11-15 | ContractNo_C200 | 101d |
| ContractNo_C470 |  | Install Landscape, Sod, Etc. - [Location] | 11d | 2025-04-16 | 2025-05-01 | ContractNo_C320 | 20d |
|  | StpD | **Step D** |  |  |  |  |  |
|  | Ph3 | **Stage 3** |  |  |  |  |  |
|  | StpA | **Step A** |  |  |  |  |  |
|  | StpB | **Step B** |  |  |  |  |  |
|  | StpC | **Step C** |  |  |  |  |  |
|  | StpD | **Step D** |  |  |  |  |  |
|  | Ph4 | **Stage 4** |  |  |  |  |  |
|  | StpA | **Step A** |  |  |  |  |  |
|  | StpB | **Step B** |  |  |  |  |  |
|  | StpC | **Step C** |  |  |  |  |  |
|  | StpD | **Step D** |  |  |  |  |  |
|  | Ph5 | **Stage 5** |  |  |  |  |  |
|  | StpA | **Step A** |  |  |  |  |  |
|  | StpB | **Step B** |  |  |  |  |  |
|  | StpC | **Step C** |  |  |  |  |  |
|  | StpD | **Step D** |  |  |  |  |  |
|  | Clo | **Close-Out** |  | 2025-04-24 | 2025-07-08 |  |  |
| ContractNo_C340 |  | MassDOT Inspection & Generate Punchlist | 21d | 2025-04-24 | 2025-05-22 | ContractNo_MS03 | 0d |
| ContractNo_C360 |  | Prepare & Submit Remaining Project Documentation | 20d | 2025-04-24 | 2025-05-21 | ContractNo_MS03 | 21d |
| ContractNo_C330 |  | Complete Punchlist & Demobilize | 30d | 2025-05-23 | 2025-07-08 | ContractNo_MS04, ContractNo_C340, ContractNo_MS02 | 0d |
|  | Pla | **Placeholder** |  | 2023-01-01 | 2024-11-30 |  |  |
| ContractNo_CAL04 |  | Cal04-7d/24hr, No Holidays (Milestones) | 100d | 2023-01-01 | 2023-04-11 |  | 819.67d |
| ContractNo_CAL03A |  | Cal03A-7d/8hr/No Holidays | 100d | 2023-01-01 | 2023-04-10 |  | 820d |
| ContractNo_CAL03 |  | Cal03-7D/8Hr, 12 Hol | 100d | 2023-01-02 | 2023-04-13 |  | 789d |
| ContractNo_CAL08 |  | Cal08-7D/8Hr, 12 Hol - Mjr Rdwy | 100d | 2023-01-02 | 2023-04-20 |  | 722d |
| ContractNo_C&RP |  | Cost & Resource Placeholder | 100d | 2023-01-03 | 2023-05-25 |  | 527d |
| ContractNo_CAL01 |  | Cal01-5D/8Hr, 12 Hol | 100d | 2023-01-03 | 2023-05-25 |  | 527d |
| ContractNo_CAL02 |  | Cal02-6D/8Hr, 12 Hol | 100d | 2023-01-03 | 2023-05-02 |  | 657d |
| ContractNo_CAL06 |  | Cal06-5D/8Hr, 12 Hol - Mjr Rdwy | 100d | 2023-01-03 | 2023-05-30 |  | 506d |
| ContractNo_CAL07 |  | Cal07-6D/8Hr, 12 Hol - Mjr Rdwy | 100d | 2023-01-03 | 2023-05-05 |  | 612d |
| ContractNo_CAL10 |  | Cal10-Winter Ineff, 5D/12 Hol | 100d | 2023-01-03 | 2023-06-16 |  | 472d |
| ContractNo_CAL11A |  | Cal11A-Winter Shut 5D/8Hr, 12Hol - Mjr Rdwy | 100d | 2023-01-03 | 2023-05-30 |  | 365d |
| ContractNo_CAL12A |  | Cal12A-Paving, 5D/12 Hol - Mjr Rdwy | 100d | 2023-01-03 | 2023-05-30 |  | 329d |
| ContractNo_CAL16 |  | Cal16-Water Access 2, 5D/12Hol | 100d | 2023-01-03 | 2023-09-07 |  | 251d |
| ContractNo_CAL05 |  | Cal05-MBTA Night No Hol | 100d | 2023-01-03 | 2023-05-25 |  | 527d |
| ContractNo_CAL18 |  | Cal18-Weekend Shutdown | 100d | 2023-01-06 | 2023-05-05 |  | 634.25d |
| ContractNo_CAL19 |  | Cal19-Saturdays Only (Advertise) | 100d | 2023-01-07 | 2024-11-30 |  | 31d |
| ContractNo_CAL11 |  | Cal11-Winter Shut 5D/8Hr, 12Hol | 100d | 2023-03-16 | 2023-08-08 |  | 334d |
| ContractNo_CAL14 |  | Cal14-Planting, 5D/12Hol - Deciduous | 100d | 2023-03-21 | 2023-11-28 |  | 153d |
| ContractNo_CAL12 |  | Cal12-Paving, 5D/12 Hol | 100d | 2023-04-03 | 2023-08-24 |  | 280d |
| ContractNo_CAL13 |  | Cal13-Planting, 5D/12Hol - Evergreen | 100d | 2023-04-18 | 2024-05-23 |  | 77d |
| ContractNo_CAL17 |  | Cal17 - Reclaimation - 5d/12hol | 100d | 2023-04-18 | 2023-09-08 |  | 205d |
| ContractNo_CAL15 |  | Cal15-Water Access1, 5D/12Hol | 100d | 2023-06-01 | 2024-06-25 |  | 92d |
|  | Deleted | **Deleted Activities** |  |  |  |  |  |

## Version 2 (data date 2026-01-01, saved 2026-01-16, file DB CST 1.4.xer)

Last finish 2025-07-08 → 2028-06-10 (+1068d).

Changed:

| ID | Task | Start | Finish | Duration | Total float | Other |
| --- | --- | --- | --- | --- | --- | --- |
| DB CCTD 1.0.1 | **Design-Build Contract Procurement** | 2023-01-03 → 2026-01-02 (+1095d) | 2023-07-22 → 2026-07-18 (+1092d) |  |  |  |
| ContractNo_Prelim | BTC Plans/Specs/Spec. Prov. accepted by MassDOT | 2023-01-03 → 2026-01-02 (+1095d) | 2023-01-03 → 2026-01-02 (+1095d) |  | 70d → 42d |  |
| ContractNo_Prelim10 | FHWA Review BTC Plans/Specs/Spec. Provisions | 2023-01-03 → 2026-01-02 (+1095d) | 2023-02-01 → 2026-01-31 (+1095d) |  | 100d → 62d |  |
| ContractNo_LOI | Advertise Request for Letters-of-Interest (LOI) | 2023-01-07 → 2026-01-03 (+1092d) | 2023-01-07 → 2026-01-03 (+1092d) |  | 6d → 1d |  |
| ContractNo_LOIP | Letters-of-Interest (LOI) Procurement | 2023-01-07 → 2026-01-03 (+1092d) | 2023-02-15 → 2026-02-11 (+1092d) |  | 37d → 2d |  |
| ContractNo_RFP20 | FHWA Concurrance to Advertise | 2023-02-01 → 2026-02-02 (+1097d) | 2023-02-01 → 2026-02-02 (+1097d) |  | 70d → 44d |  |
| ContractNo_LOID | Letters-of-Interest (LOI) Due | 2023-02-15 → 2026-02-11 (+1092d) | 2023-02-15 → 2026-02-11 (+1092d) |  | 26d → 2d |  |
| ContractNo_RFQ | Issue Request for Qualifications (RFQ) | 2023-02-16 → 2026-02-12 (+1092d) | 2023-02-16 → 2026-02-12 (+1092d) |  | 26d → 2d |  |
| ContractNo_RFQP | Statement of Qualifications Prepared | 2023-02-16 → 2026-02-12 (+1092d) | 2023-03-15 → 2026-03-11 (+1092d) |  | 37d → 2d |  |
| ContractNo_RFQD | Statement of Qualifications Due | 2023-03-15 → 2026-03-11 (+1092d) | 2023-03-15 → 2026-03-11 (+1092d) |  | 26d → 2d |  |
| ContractNo_ShList | Shortlist of Proposers Selected/Notified | 2023-03-16 → 2026-03-12 (+1092d) | 2023-04-04 → 2026-03-31 (+1092d) |  | 39d → 4d |  |
| ContractNo_RFP10 | Advertise Request for Proposals | 2023-04-08 → 2026-04-04 (+1092d) | 2023-04-08 → 2026-04-04 (+1092d) |  | 6d → 1d |  |
| ContractNo_RFP | Release Request for Proposals (RFP) | 2023-04-10 → 2026-04-06 (+1092d) | 2023-04-10 → 2026-04-06 (+1092d) |  | 26d → 1d |  |
| ContractNo_RFPP | Proposers Prepare Proposals | 2023-04-10 → 2026-04-06 (+1092d) | 2023-05-22 → 2026-05-18 (+1092d) |  | 37d → 1d |  |
| ContractNo_RFPP20 | Pre-Proposal Meeting | 2023-04-10 → 2026-04-06 (+1092d) | 2023-04-10 → 2026-04-06 (+1092d) |  | 44d → 20d |  |
| ContractNo_RFPP30 | ATC Meetings | 2023-04-11 → 2026-04-07 (+1092d) | 2023-04-13 → 2026-04-09 (+1092d) |  | 44d → 20d |  |
| ContractNo_RFPP50 | ATC Proposals Due | 2023-04-14 → 2026-04-10 (+1092d) | 2023-04-14 → 2026-04-10 (+1092d) |  | 44d → 20d |  |
| ContractNo_RFPP40 | Final RFP Questions Due | 2023-05-15 → 2026-05-11 (+1092d) | 2023-05-15 → 2026-05-11 (+1092d) |  | 25d → 1d |  |
| ContractNo_RFPP10 | Technical and Price Proposals Due | 2023-05-22 → 2026-05-18 (+1092d) | 2023-05-22 → 2026-05-18 (+1092d) |  | 25d → 1d |  |
| ContractNo_RFPD00 | Oral Presentation of Design-Build Proposals | 2023-05-31 → 2026-05-27 (+1092d) | 2023-06-01 → 2026-05-28 (+1092d) |  | 25d → 1d |  |
| ContractNo_RFPD10 | Scoring of Technical Proposals | 2023-06-02 → 2026-05-29 (+1092d) | 2023-06-05 → 2026-06-01 (+1092d) |  | 25d → 1d |  |
| ContractNo_BID | Public Price Bid Opening | 2023-06-06 → 2026-06-02 (+1092d) | 2023-06-06 → 2026-06-02 (+1092d) |  | 25d → 1d |  |
| ContractNo_NOA | Issue Notice of Award\Project Start | 2023-06-08 → 2026-06-04 (+1092d) | 2023-07-22 → 2026-07-18 (+1092d) |  | 39d → 1d |  |
| 1 | **Milestones** | 2023-07-22 → 2026-07-18 (+1092d) | 2025-07-08 → 2028-06-10 (+1068d) |  |  |  |
| 1 | **General** | 2023-07-22 → 2026-07-18 (+1092d) | 2025-07-08 → 2028-06-10 (+1068d) |  |  |  |
| ContractNo_NTP | Issue Design-Builder Notice-to-Proceed (NTP) | 2023-07-22 → 2026-07-18 (+1092d) | 2023-07-22 → 2026-07-18 (+1092d) |  | 39.67d → 1.67d |  |
| ContractNo_AR01 | Access Restraint: Relocate Util before Bridge Demo | 2024-04-10 → 2027-04-30 (+1115d) | 2024-04-10 → 2027-04-30 (+1115d) |  | 97.87d → 0d | constraint none → start on 2027-04-30 |
| ContractNo_MS03 | MS#03 - Full Beneficial Use (FBU) | 2025-04-23 → 2028-04-20 (+1093d) | 2025-04-23 → 2028-04-20 (+1093d) |  |  | constraint finish on or before 2026-10-01 → finish on or before 2029-10-01 |
| ContractNo_MS04 | MS#04 - Perform Final Traffic Move | 2025-04-23 → 2028-04-20 (+1093d) | 2025-04-23 → 2028-04-20 (+1093d) |  |  | constraint none → finish on or before 2029-10-01 |
| ContractNo_MS02 | MS#02 - Substantial Completion (SC) | 2025-05-22 → 2028-05-11 (+1085d) | 2025-05-22 → 2028-05-11 (+1085d) |  |  | constraint finish on or before 2026-10-01 → finish on or before 2029-10-01 |
| ContractNo_MS01 | MS#01 - Field Completion (CFC) | 2025-07-08 → 2028-06-10 (+1068d) | 2025-07-08 → 2028-06-10 (+1068d) |  |  | constraint finish on or before 2026-11-15 → finish on or before 2029-11-15 |
| 2 | **Durations** | 2023-07-22 → 2026-07-18 (+1092d) | 2025-07-08 → 2028-06-10 (+1068d) |  |  |  |
| ContractNo_1000 | Construction Contract Duration (NTP to FBU) | 2023-07-22 → 2026-07-18 (+1092d) | 2025-04-23 → 2028-04-20 (+1093d) | 641d → 642d |  |  |
| ContractNo_1010 | Construction Contract Duration (NTP to SC) | 2023-07-22 → 2026-07-18 (+1092d) | 2025-05-22 → 2028-05-11 (+1085d) | 670d → 663d |  |  |
| ContractNo_1020 | Construction Contract Duration (NTP to CFC) | 2023-07-22 → 2026-07-18 (+1092d) | 2025-07-08 → 2028-06-10 (+1068d) | 717d → 693d |  |  |
| ContractNo_1030 | Construction Contract Duration (NTP to AR01) | 2023-07-22 → 2026-07-18 (+1092d) | 2024-04-10 → 2027-04-30 (+1115d) | 262.8d → 285.8d | 97.87d → 0d |  |
| 2 | **Submittals & Procurements** | 2023-07-24 → 2026-07-20 (+1092d) | 2024-12-05 → 2027-12-03 (+1093d) |  |  |  |
| 1 | **Early Release Design Packages** | 2023-07-24 → 2026-07-20 (+1092d) | 2024-10-17 → 2027-10-19 (+1097d) |  |  |  |
| 3 | **Geotechnical Report** | 2023-07-24 → 2026-07-20 (+1092d) | 2023-11-17 → 2026-11-13 (+1092d) |  |  |  |
| ContractNo_2640 | Prepare & Submit Subsurface Investigation Plan | 2023-07-24 → 2026-07-20 (+1092d) | 2023-08-04 → 2026-07-31 (+1092d) |  | 363d → 349d |  |
| ContractNo_2660 | Review & Approve Subsurface Investigation Plan | 2023-08-05 → 2026-08-01 (+1092d) | 2023-08-14 → 2026-08-10 (+1092d) |  | 532d → 511d |  |
| ContractNo_2650 | Schedule/Perform Geotech Borings & Test Pits | 2023-08-15 → 2026-08-11 (+1092d) | 2023-09-26 → 2026-09-22 (+1092d) |  | 362d → 348d |  |
| ContractNo_1680 | Prepare Geotechnical Report | 2023-09-27 → 2026-09-23 (+1092d) | 2023-10-10 → 2026-10-05 (+1091d) |  | 362d → 348d |  |
| ContractNo_1950 | Schedule & Conduct OTS Review - Geotechnical Report | 2023-10-11 → 2026-10-06 (+1091d) | 2023-10-12 → 2026-10-07 (+1091d) |  | 362d → 348d |  |
| ContractNo_1940 | Submit Geotechnical Report | 2023-10-13 → 2026-10-08 (+1091d) | 2023-10-18 → 2026-10-14 (+1092d) |  | 362d → 348d |  |
| ContractNo_2050 | Review & Approve Geotechnical Report | 2023-10-19 → 2026-10-15 (+1092d) | 2023-11-17 → 2026-11-13 (+1092d) |  | 552d → 531d |  |
| 1 | **Drilled Shafts** | 2023-10-19 → 2026-10-15 (+1092d) | 2024-01-20 → 2027-01-16 (+1092d) |  |  |  |
| ContractNo_1740 | Prepare Drilled Shafts Design | 2023-10-19 → 2026-10-15 (+1092d) | 2023-11-01 → 2026-10-28 (+1092d) |  | 362d → 348d |  |
| ContractNo_1990 | Schedule & Conduct OTS Review - Drilled Shafts Design | 2023-11-02 → 2026-10-29 (+1092d) | 2023-11-02 → 2026-10-29 (+1092d) |  | 362d → 348d |  |
| ContractNo_1980 | Submit Drilled Shafts Design | 2023-11-03 → 2026-10-30 (+1092d) | 2023-11-07 → 2026-11-03 (+1092d) |  | 362d → 348d |  |
| ContractNo_2060 | Review & Approve Drilled Shafts Design | 2023-11-08 → 2026-11-04 (+1092d) | 2023-12-07 → 2026-12-03 (+1092d) |  | 532d → 511d |  |
| ContractNo_1750 | Comment Resolution & Reissue Drilled Shafts Design | 2023-12-08 → 2026-12-04 (+1092d) | 2023-12-21 → 2026-12-17 (+1092d) |  | 363d → 349d |  |
| ContractNo_1890 | Procure Drilled Shaft Casings | 2023-12-22 → 2026-12-18 (+1092d) | 2024-01-20 → 2027-01-16 (+1092d) |  | 535d → 511d |  |
| 4 | **Substructure Rebar** | 2023-07-24 → 2026-07-20 (+1092d) | 2024-01-29 → 2027-01-25 (+1092d) |  |  |  |
| ContractNo_1780 | Prepare Early Release - Substructure Design | 2023-07-24 → 2026-07-20 (+1092d) | 2023-11-29 → 2026-11-25 (+1092d) |  | 359d → 341d |  |
| ContractNo_2010 | Schedule & Conduct OTS Review - Early Release - Substructure Design | 2023-11-30 → 2026-11-27 (+1093d) | 2023-12-08 → 2026-12-07 (+1095d) |  | 359d → 341d |  |
| ContractNo_2000 | Submit Early Release - Substructure Design | 2023-12-11 → 2026-12-08 (+1093d) | 2023-12-14 → 2026-12-11 (+1093d) |  | 359d → 341d |  |
| ContractNo_2070 | Review & Approve Early Release - Substructure Design | 2023-12-15 → 2026-12-12 (+1093d) | 2024-01-13 → 2027-01-10 (+1093d) |  | 527d → 501d |  |
| ContractNo_1790 | Comment Resolution & Reissue Early Release - Substructure Design | 2024-01-16 → 2027-01-11 (+1091d) | 2024-01-29 → 2027-01-25 (+1092d) |  | 359d → 345d |  |
| 2 | **Structural Steel** | 2023-07-24 → 2026-07-20 (+1092d) | 2024-10-17 → 2027-10-19 (+1097d) |  |  |  |
| ContractNo_1760 | Prepare Early Release - Superstructure Design | 2023-07-24 → 2026-07-20 (+1092d) | 2023-11-29 → 2026-11-25 (+1092d) |  | 28d → 14d |  |
| ContractNo_1970 | Schedule & Conduct OTS Review - Early Release - Superstructure Design | 2023-11-30 → 2026-11-27 (+1093d) | 2023-11-30 → 2026-11-27 (+1093d) |  | 28d → 14d |  |
| ContractNo_1960 | Submit Early Release - Superstructure Design | 2023-12-01 → 2026-11-30 (+1095d) | 2023-12-01 → 2026-11-30 (+1095d) |  | 28d → 14d |  |
| ContractNo_1770 | Review & Approve Early Release - Superstructure Design | 2023-12-02 → 2026-12-01 (+1095d) | 2023-12-31 → 2026-12-30 (+1095d) |  | 42d → 20d |  |
| ContractNo_2040 | Comment Resolution & Reissue Early Release - Superstructure Design | 2024-01-02 → 2026-12-31 (+1094d) | 2024-01-08 → 2027-01-07 (+1095d) |  | 28d → 12d |  |
| ContractNo_1710 | Prepare & Submit Structural Steel Shop Drawings | 2024-01-09 → 2027-01-08 (+1095d) | 2024-03-06 → 2027-03-08 (+1097d) |  | 28d → 12d |  |
| ContractNo_1720 | Review & Approve Structural Steel Shop Drawings | 2024-03-07 → 2027-03-09 (+1097d) | 2024-04-05 → 2027-04-07 (+1097d) |  | 41d → 16d |  |
| ContractNo_1730 | Procure Structural Steel Stage 1 | 2024-04-06 → 2027-04-08 (+1097d) | 2024-06-19 → 2027-06-21 (+1097d) |  | 41d → 16d |  |
| ContractNo_1800 | Procure Structural Steel Stage 2 | 2024-06-20 → 2027-06-22 (+1097d) | 2024-10-17 → 2027-10-19 (+1097d) |  | 264d → 235d |  |
| 9 | **Bridge Bearings Design** | 2024-01-09 → 2027-01-08 (+1095d) | 2024-03-07 → 2027-03-07 (+1095d) |  |  |  |

| ID | Task | Start | Finish | Total float |
| --- | --- | --- | --- | --- |
| ContractNo_1830 | Prepare & Submit Early Release Bridge Bearings | 2024-01-09 → 2027-01-08 (+1095d) | 2024-02-06 → 2027-02-05 (+1095d) | 333d → 316d |
| ContractNo_1840 | Review & Approve Early Release Bridge Bearings | 2024-02-07 → 2027-02-06 (+1095d) | 2024-03-07 → 2027-03-07 (+1095d) | 488d → 461d |
| 10 | **Bridge Scuppers Design** | 2024-01-09 → 2027-01-08 (+1095d) | 2024-04-12 → 2027-04-14 (+1097d) |  |
| ContractNo_1850 | Prepare & Submit Bridge Scupper Design | 2024-01-09 → 2027-01-08 (+1095d) | 2024-03-13 → 2027-03-15 (+1097d) | 308d → 291d |
| ContractNo_1860 | Review & Approve Bridge Scupper Design | 2024-03-14 → 2027-03-16 (+1097d) | 2024-04-12 → 2027-04-14 (+1097d) | 452d → 423d |
| 11 | **Bridge Joint Design** | 2024-01-09 → 2027-01-08 (+1095d) | 2024-04-12 → 2027-04-14 (+1097d) |  |
| ContractNo_1870 | Prepare & Submit Bridge Joint Design | 2024-01-09 → 2027-01-08 (+1095d) | 2024-03-13 → 2027-03-15 (+1097d) | 308d → 291d |
| ContractNo_1880 | Review & Approve Bridge Joint Design | 2024-03-14 → 2027-03-16 (+1097d) | 2024-04-12 → 2027-04-14 (+1097d) | 452d → 423d |
| 2 | **Projectwide Submittals** | 2023-07-24 → 2026-07-20 (+1092d) | 2024-01-04 → 2027-01-01 (+1093d) |  |
| 1 | **Project Schedule** | 2023-07-24 → 2026-07-20 (+1092d) | 2024-01-04 → 2027-01-01 (+1093d) |  |
| ContractNo_2080 | Prepare & Submit Initial Baseline Project Schedule (Logic Only) | 2023-07-24 → 2026-07-20 (+1092d) | 2023-09-18 → 2026-09-14 (+1092d) | 376d → 361d |
| ContractNo_2090 | Review & Comment on Initial Baseline Project Schedule (Logic Only) | 2023-09-19 → 2026-09-15 (+1092d) | 2023-10-18 → 2026-10-14 (+1092d) | 551d → 529d |
| ContractNo_2220 | Prepare & Submit Baseline Schedule (Logic Only) (Rev 1) | 2023-10-19 → 2026-10-15 (+1092d) | 2023-11-08 → 2026-11-04 (+1092d) | 375d → 360d |
| ContractNo_2230 | Review & Comment on Baseline Schedule (Logic Only (Rev 1) | 2023-11-09 → 2026-11-05 (+1092d) | 2023-11-23 → 2026-11-19 (+1092d) | 551d → 528d |
| ContractNo_2620 | Prepare & Submit Cost & Resource Loaded Baseline Schedule | 2023-11-24 → 2026-11-20 (+1092d) | 2023-12-14 → 2026-12-11 (+1093d) | 375d → 359d |
| ContractNo_2630 | Review & Approve Cost & Resource Loaded Baseline Schedule | 2023-12-15 → 2026-12-12 (+1093d) | 2024-01-04 → 2027-01-01 (+1093d) | 551d → 526d |
| 2 | **Project Management Plan** | 2023-07-24 → 2026-07-20 (+1092d) | 2023-10-01 → 2026-09-27 (+1092d) |  |
| ContractNo_2100 | Prepare & Submit Project Management Plan | 2023-07-24 → 2026-07-20 (+1092d) | 2023-09-01 → 2026-08-28 (+1092d) | 439d → 424d |
| ContractNo_2110 | Review & Approve Project Management Plan | 2023-09-02 → 2026-08-29 (+1092d) | 2023-10-01 → 2026-09-27 (+1092d) | 646d → 622d |
| 4 | **Public Participation Plan** | 2023-07-24 → 2026-07-20 (+1092d) | 2023-10-01 → 2026-09-27 (+1092d) |  |
| ContractNo_2120 | Prepare & Submit Public Participation Plan | 2023-07-24 → 2026-07-20 (+1092d) | 2023-09-01 → 2026-08-28 (+1092d) | 439d → 424d |
| ContractNo_2160 | Setup Project Webpage | 2023-07-24 → 2026-07-20 (+1092d) | 2023-08-18 → 2026-08-14 (+1092d) | 469d → 454d |
| ContractNo_2130 | Review & Approve Public Participation Plan | 2023-09-02 → 2026-08-29 (+1092d) | 2023-10-01 → 2026-09-27 (+1092d) | 646d → 622d |
| 5 | **Health & Safety Plan** | 2023-07-24 → 2026-07-20 (+1092d) | 2023-09-17 → 2026-09-13 (+1092d) |  |
| ContractNo_2140 | Prepare & Submit Health & Safety Plan | 2023-07-24 → 2026-07-20 (+1092d) | 2023-08-18 → 2026-08-14 (+1092d) | 449d → 434d |
| ContractNo_2150 | Review & Approve Health & Safety Plan | 2023-08-19 → 2026-08-15 (+1092d) | 2023-09-17 → 2026-09-13 (+1092d) | 660d → 636d |
| 3 | **Environmental Submittals** | 2023-07-24 → 2026-07-20 (+1092d) | 2023-12-29 → 2026-12-25 (+1092d) |  |
| 8 | **Groundwater & Soil Management Plan** | 2023-07-24 → 2026-07-20 (+1092d) | 2023-10-25 → 2026-10-21 (+1092d) |  |
| ContractNo_2520 | Prepare & Submit Groundwater & Soil Management Plan | 2023-07-24 → 2026-07-20 (+1092d) | 2023-09-25 → 2026-09-21 (+1092d) | 167d → 152d |
| ContractNo_2530 | Review & Approve Groundwater & Soil Management Plan | 2023-09-26 → 2026-09-22 (+1092d) | 2023-10-25 → 2026-10-21 (+1092d) | 244d → 224d |
| 10 | **Noise Control Plan** | 2023-07-24 → 2026-07-20 (+1092d) | 2023-10-01 → 2026-09-27 (+1092d) |  |
| ContractNo_2540 | Prepare & Submit Noise Control Plan | 2023-07-24 → 2026-07-20 (+1092d) | 2023-09-01 → 2026-08-28 (+1092d) | 439d → 424d |
| ContractNo_2550 | Review & Approve Noise Control Plan | 2023-09-02 → 2026-08-29 (+1092d) | 2023-10-01 → 2026-09-27 (+1092d) | 646d → 622d |
| 11 | **Dust Control Plan** | 2023-07-24 → 2026-07-20 (+1092d) | 2023-10-01 → 2026-09-27 (+1092d) |  |
| ContractNo_2560 | Prepare & Submit Dust Control Plan | 2023-07-24 → 2026-07-20 (+1092d) | 2023-09-01 → 2026-08-28 (+1092d) | 439d → 424d |
| ContractNo_2570 | Review & Approve Dust Control Plan | 2023-09-02 → 2026-08-29 (+1092d) | 2023-10-01 → 2026-09-27 (+1092d) | 646d → 622d |
| 13 | **Invasive Species Management Plan** | 2023-07-24 → 2026-07-20 (+1092d) | 2023-10-18 → 2026-10-14 (+1092d) |  |
| ContractNo_2600 | Prepare & Submit Invasive Species Management Plan | 2023-07-24 → 2026-07-20 (+1092d) | 2023-09-18 → 2026-09-14 (+1092d) | 429d → 414d |
| ContractNo_2610 | Review & Approve Invasive Species Management Plan | 2023-09-19 → 2026-09-15 (+1092d) | 2023-10-18 → 2026-10-14 (+1092d) | 629d → 605d |
| 12 | **Dredge Material Plan** | 2023-07-24 → 2026-07-20 (+1092d) | 2023-12-29 → 2026-12-25 (+1092d) |  |
| ContractNo_2580 | Prepare & Submit Dredge Material Plan | 2023-07-24 → 2026-07-20 (+1092d) | 2023-11-29 → 2026-11-25 (+1092d) | 379d → 364d |
| ContractNo_2590 | Review & Approve Dredge Material Plan | 2023-11-30 → 2026-11-26 (+1092d) | 2023-12-29 → 2026-12-25 (+1092d) | 557d → 533d |
| 4 | **Design Submittals** | 2023-07-24 → 2026-07-20 (+1092d) | 2024-12-05 → 2027-12-03 (+1093d) |  |
| 1 | **Formal Bridge Sketch Plan** | 2023-07-24 → 2026-07-20 (+1092d) | 2023-11-02 → 2026-10-29 (+1092d) |  |
| ContractNo_1690 | Prepare Formal Bridge Sketch Plan | 2023-07-24 → 2026-07-20 (+1092d) | 2023-09-11 → 2026-09-04 (+1089d) | 46d → 33d |
| ContractNo_1930 | Schedule & Conduct OTS Review - Formal Bridge Sketch Plan | 2023-09-12 → 2026-09-08 (+1092d) | 2023-09-13 → 2026-09-09 (+1092d) | 46d → 33d |
| ContractNo_1920 | Submit Formal Bridge Sketch Plan | 2023-09-14 → 2026-09-10 (+1092d) | 2023-09-19 → 2026-09-15 (+1092d) | 46d → 33d |
| ContractNo_2020 | Review & Approve Formal Bridge Sketch Plan | 2023-09-20 → 2026-09-16 (+1092d) | 2023-10-19 → 2026-10-15 (+1092d) | 68d → 48d |
| ContractNo_1700 | Comment Resolution & Reissue Formal Bridge Sketch Plan | 2023-10-20 → 2026-10-16 (+1092d) | 2023-11-02 → 2026-10-29 (+1092d) | 46d → 32d |
| 2 | **First Structural Design - Bridge** | 2023-10-20 → 2026-10-16 (+1092d) | 2024-02-02 → 2027-02-03 (+1097d) |  |
| ContractNo_2670 | Prepare First Structural Bridge | 2023-10-20 → 2026-10-16 (+1092d) | 2023-12-12 → 2026-12-09 (+1093d) | 142d → 129d |
| ContractNo_2770 | Schedule & Conduct OTS Review - First Structural Bridge | 2023-12-13 → 2026-12-10 (+1093d) | 2023-12-14 → 2026-12-11 (+1093d) | 142d → 129d |
| ContractNo_2780 | Finalize First Structural Bridge | 2023-12-15 → 2026-12-14 (+1095d) | 2023-12-18 → 2026-12-15 (+1093d) | 142d → 129d |
| ContractNo_2790 | Formal QC Review First Structural Bridge | 2023-12-19 → 2026-12-16 (+1093d) | 2023-12-21 → 2026-12-18 (+1093d) | 142d → 129d |
| ContractNo_2800 | Submit First Structural Bridge | 2023-12-22 → 2026-12-21 (+1095d) | 2023-12-22 → 2026-12-21 (+1095d) | 142d → 129d |
| ContractNo_2970 | Review & Approve First Structural Bridge | 2023-12-23 → 2026-12-22 (+1095d) | 2024-01-21 → 2027-01-20 (+1095d) | 211d → 189d |
| ContractNo_2680 | Comment Resolution & Reissue First Structural Bridge | 2024-01-22 → 2027-01-21 (+1095d) | 2024-02-02 → 2027-02-03 (+1097d) | 146d → 131d |
| 5 | **Second Structural Design - Bridge** | 2024-02-05 → 2027-02-04 (+1095d) | 2024-04-05 → 2027-04-08 (+1098d) |  |
| ContractNo_2710 | Prepare Second Structural Bridge | 2024-02-05 → 2027-02-04 (+1095d) | 2024-02-09 → 2027-02-10 (+1097d) | 274d → 257d |
| ContractNo_2850 | Schedule & Conduct OTS Review - Second Structural Bridge | 2024-02-12 → 2027-02-11 (+1095d) | 2024-02-13 → 2027-02-12 (+1095d) | 274d → 257d |
| ContractNo_2860 | Finalize Second Structural Bridge | 2024-02-14 → 2027-02-16 (+1098d) | 2024-02-15 → 2027-02-17 (+1098d) | 274d → 257d |
| ContractNo_2870 | Formal QC Review Second Structural Bridge | 2024-02-16 → 2027-02-18 (+1098d) | 2024-02-21 → 2027-02-22 (+1097d) | 274d → 257d |
| ContractNo_2880 | Submit Second Structural Bridge | 2024-02-22 → 2027-02-23 (+1097d) | 2024-02-22 → 2027-02-23 (+1097d) | 274d → 257d |
| ContractNo_2990 | Review & Approve Second Structural Bridge | 2024-02-23 → 2027-02-24 (+1097d) | 2024-03-23 → 2027-03-25 (+1097d) | 402d → 375d |
| ContractNo_2720 | Comment Resolution & Reissue Second Structural Bridge | 2024-03-25 → 2027-03-26 (+1096d) | 2024-04-05 → 2027-04-08 (+1098d) | 274d → 256d |
| 4 | **75% Design - Highway** | 2024-02-05 → 2027-02-04 (+1095d) | 2024-07-19 → 2027-07-20 (+1096d) |  |
| ContractNo_2690 | Prepare 75% Design - Highway | 2024-02-05 → 2027-02-04 (+1095d) | 2024-05-21 → 2027-05-21 (+1095d) | 146d → 131d |
| ContractNo_2810 | Schedule & Conduct OTS Review - 75% Design - Highway | 2024-05-22 → 2027-05-24 (+1097d) | 2024-05-23 → 2027-05-25 (+1097d) | 146d → 131d |
| ContractNo_2820 | Finalize 75% Design - Highway | 2024-05-24 → 2027-05-26 (+1097d) | 2024-05-28 → 2027-05-27 (+1094d) | 146d → 131d |
| ContractNo_2830 | Formal QC Review 75% Design - Highway | 2024-05-29 → 2027-05-28 (+1094d) | 2024-05-31 → 2027-06-02 (+1097d) | 146d → 131d |

| ID | Task | Start | Finish | Total float |
| --- | --- | --- | --- | --- |
| ContractNo_2840 | Submit 75% Design - Highway | 2024-06-03 → 2027-06-03 (+1095d) | 2024-06-03 → 2027-06-03 (+1095d) | 146d → 131d |
| ContractNo_2980 | Review & Approve 75% Design - Highway | 2024-06-04 → 2027-06-04 (+1095d) | 2024-07-03 → 2027-07-03 (+1095d) | 215d → 190d |
| ContractNo_2700 | Comment Resolution & Reissue 75% Design - Highway | 2024-07-05 → 2027-07-06 (+1096d) | 2024-07-18 → 2027-07-19 (+1096d) | 145d → 128d |
| ContractNo_3570 | Submit 75% Design - Highway - REV1 (15 Days if required) | 2024-07-19 → 2027-07-20 (+1096d) | 2024-07-19 → 2027-07-20 (+1096d) | 145d → 128d |
| ContractNo_3580 | Review & Approve 75% Design - Highway - REV-1 (30 Days if required) | 2024-07-19 → 2027-07-20 (+1096d) | 2024-07-19 → 2027-07-20 (+1096d) | 215d → 189d |
| 3 | **100% Design - Highway** | 2024-07-19 → 2027-07-20 (+1096d) | 2024-10-10 → 2027-10-08 (+1093d) |  |
| ContractNo_2750 | Prepare 100% Design - Highway | 2024-07-19 → 2027-07-20 (+1096d) | 2024-08-15 → 2027-08-16 (+1096d) | 145d → 128d |
| ContractNo_2890 | Schedule & Conduct OTS Review - 100% Design - Highway | 2024-08-16 → 2027-08-17 (+1096d) | 2024-08-19 → 2027-08-18 (+1094d) | 145d → 128d |
| ContractNo_2900 | Finalize 100% Design - Highway | 2024-08-20 → 2027-08-19 (+1094d) | 2024-08-21 → 2027-08-20 (+1094d) | 145d → 128d |
| ContractNo_2910 | Formal QC Review 100% Design - Highway | 2024-08-22 → 2027-08-23 (+1096d) | 2024-08-26 → 2027-08-25 (+1094d) | 145d → 128d |
| ContractNo_2920 | Submit 100% Design - Highway | 2024-08-27 → 2027-08-26 (+1094d) | 2024-08-27 → 2027-08-26 (+1094d) | 145d → 128d |
| ContractNo_3000 | Review & Approve 100% Design - Highway (MassDOT) | 2024-08-28 → 2027-08-27 (+1094d) | 2024-09-26 → 2027-09-25 (+1094d) | 215d → 191d |
| ContractNo_2760 | Comment Resolution & Reissue 100% Design - Highway | 2024-09-27 → 2027-09-27 (+1095d) | 2024-10-10 → 2027-10-08 (+1093d) | 145d → 129d |
| 7 | **Final Design - Bridge & Highway** | 2024-10-11 → 2027-10-12 (+1096d) | 2024-12-05 → 2027-12-03 (+1093d) |  |
| ContractNo_2730 | Prepare "RFC" Final Design - Bridge & Highway | 2024-10-11 → 2027-10-12 (+1096d) | 2024-10-24 → 2027-10-22 (+1093d) | 145d → 129d |
| ContractNo_2930 | Schedule & Conduct OTS Review - "RFC" Final Design - Bridge & Highway | 2024-10-25 → 2027-10-25 (+1095d) | 2024-10-28 → 2027-10-26 (+1093d) | 145d → 129d |
| ContractNo_2940 | Finalize "RFC" Final Design - Bridge & Highway | 2024-10-29 → 2027-10-27 (+1093d) | 2024-10-30 → 2027-10-28 (+1093d) | 145d → 129d |
| ContractNo_2950 | Formal QC Review "RFC" Final Design - Bridge & Highway | 2024-10-31 → 2027-10-29 (+1093d) | 2024-11-04 → 2027-11-02 (+1093d) | 145d → 129d |
| ContractNo_2960 | Submit "RFC" Final Design - Bridge & Highway | 2024-11-05 → 2027-11-03 (+1093d) | 2024-11-05 → 2027-11-03 (+1093d) | 145d → 129d |
| ContractNo_2740 | Review & Approve "RFC" Final Design - Bridge & Highway (MassDOT) | 2024-11-06 → 2027-11-04 (+1093d) | 2024-12-05 → 2027-12-03 (+1093d) | 215d → 190d |
| 5 | **Early Action Construction Submittals** | 2023-07-24 → 2026-07-20 (+1092d) | 2023-11-01 → 2026-10-28 (+1092d) |  |
| 5 | **RTTM** | 2023-07-24 → 2026-07-20 (+1092d) | 2023-11-01 → 2026-10-28 (+1092d) |  |
| ContractNo_1470 | Prepare & Submit RTTM System | 2023-07-24 → 2026-07-20 (+1092d) | 2023-08-18 → 2026-08-14 (+1092d) | 45.6d → 15d |
| ContractNo_1540 | Review & Approve RTTM System | 2023-08-19 → 2026-08-15 (+1092d) | 2023-09-17 → 2026-09-13 (+1092d) | 67.6d → 21d |
| ContractNo_1480 | Comment Resolution & Reissue RTTM System | 2023-09-18 → 2026-09-14 (+1092d) | 2023-10-02 → 2026-09-28 (+1092d) | 47.6d → 15d |
| ContractNo_1490 | Procure RTTM System | 2023-10-02 → 2026-09-28 (+1092d) | 2023-11-01 → 2026-10-28 (+1092d) | 69.6d → 22d |
| 1 | **Quality Management Plan (QMP)** | 2023-07-24 → 2026-07-20 (+1092d) | 2023-09-17 → 2026-09-13 (+1092d) |  |
| ContractNo_1040 | Prepare & Submit Quality Management Plan | 2023-07-24 → 2026-07-20 (+1092d) | 2023-08-18 → 2026-08-14 (+1092d) | 449d → 434d |
| ContractNo_1050 | Review & Approve Quality Management Plan | 2023-08-19 → 2026-08-15 (+1092d) | 2023-09-17 → 2026-09-13 (+1092d) | 660d → 636d |
| 7 | **Bathymetric Survey** | 2023-07-24 → 2026-07-20 (+1092d) | 2023-08-15 → 2026-08-11 (+1092d) |  |
| ContractNo_1360 | Schedule & Conduct Bathymetric Survey | 2023-07-24 → 2026-07-20 (+1092d) | 2023-08-01 → 2026-07-28 (+1092d) | 452d → 437d |
| ContractNo_1370 | Prepare & Submit Bathymetric Survey Report | 2023-08-02 → 2026-07-29 (+1092d) | 2023-08-15 → 2026-08-11 (+1092d) | 452d → 437d |
| 3 | **Final Hydraulic & Scour Analysis Report** | 2023-08-16 → 2026-08-12 (+1092d) | 2023-09-13 → 2026-09-09 (+1092d) |  |
| ContractNo_1380 | Prepare & Submit Final Hydraulic & Scour Analysis Report | 2023-08-16 → 2026-08-12 (+1092d) | 2023-09-13 → 2026-09-09 (+1092d) | 452d → 437d |
| 2 | **Temporary Trestle Design** | 2023-07-24 → 2026-07-20 (+1092d) | 2023-10-19 → 2026-10-15 (+1092d) |  |
| ContractNo_1390 | Prepare & Submit Temporary Trestle Design | 2023-07-24 → 2026-07-20 (+1092d) | 2023-08-15 → 2026-08-11 (+1092d) | 428.6d → 411.6d |
| ContractNo_1510 | Review & Approve Temporary Trestle | 2023-08-16 → 2026-08-12 (+1092d) | 2023-09-14 → 2026-09-10 (+1092d) | 628.6d → 602.6d |
| ContractNo_1400 | Comment Resolution & Reissue Temporary Trestle Design | 2023-09-15 → 2026-09-11 (+1092d) | 2023-09-29 → 2026-09-25 (+1092d) | 428.6d → 411.6d |
| ContractNo_1410 | Procure Temporary Trestle | 2023-09-29 → 2026-09-25 (+1092d) | 2023-10-19 → 2026-10-15 (+1092d) | 628.6d → 604.6d |
| 6 | **Support of Excavation Design** | 2023-07-24 → 2026-07-20 (+1092d) | 2023-10-21 → 2026-10-14 (+1089d) |  |
| ContractNo_1610 | Prepare & Submit Support of Excavation Design | 2023-07-24 → 2026-07-20 (+1092d) | 2023-09-01 → 2026-08-28 (+1092d) | 427d → 410d |
| ContractNo_1620 | Review & Approve Support of Excavation Design | 2023-09-02 → 2026-08-29 (+1092d) | 2023-10-01 → 2026-09-27 (+1092d) | 627d → 602d |
| ContractNo_1630 | Comment Resolution & Reissue Support of Excavation Design | 2023-10-02 → 2026-09-28 (+1092d) | 2023-10-16 → 2026-10-09 (+1089d) | 428d → 411d |
| ContractNo_1500 | Procure Support of Excavation | 2023-10-17 → 2026-10-10 (+1089d) | 2023-10-21 → 2026-10-14 (+1089d) | 626d → 605d |
| 4 | **Existing Sewer Line Protection Plan** | 2023-07-24 → 2026-07-20 (+1092d) | 2023-09-29 → 2026-09-25 (+1092d) |  |
| ContractNo_1420 | Prepare & Submit Existing Sewer Line Protection Plan | 2023-07-24 → 2026-07-20 (+1092d) | 2023-08-17 → 2026-08-13 (+1092d) | 441d → 423d |
| ContractNo_1520 | Review & Approve Existing Sewer Line Protection Plan | 2023-08-18 → 2026-08-14 (+1092d) | 2023-09-16 → 2026-09-12 (+1092d) | 646d → 621d |
| ContractNo_1430 | Comment Resolution & Reissue Existing Sewer Line Protection Plan | 2023-09-01 → 2026-08-28 (+1092d) | 2023-09-18 → 2026-09-14 (+1092d) | 440d → 425d |
| ContractNo_1460 | Conduct CCTV Inspection of Existing Sanitary Sewer & Submit Report | 2023-09-18 → 2026-09-14 (+1092d) | 2023-09-29 → 2026-09-25 (+1092d) | 440d → 425d |
| 9 | **Stormwater Management Plan** | 2023-07-24 → 2026-07-20 (+1092d) | 2023-09-19 → 2026-09-15 (+1092d) |  |
| ContractNo_1440 | Prepare & Submit Stormwater Management Plan | 2023-07-24 → 2026-07-20 (+1092d) | 2023-07-28 → 2026-07-24 (+1092d) | 192d → 177d |
| ContractNo_1560 | Schedule & Conduct Over the Shoulder - Stormwater Management Plan | 2023-07-31 → 2026-07-27 (+1092d) | 2023-08-04 → 2026-07-31 (+1092d) | 192d → 177d |
| ContractNo_1530 | Review & Approve Stormwater Management Plan | 2023-08-05 → 2026-08-01 (+1092d) | 2023-09-03 → 2026-08-30 (+1092d) | 281d → 261d |
| ContractNo_1450 | Comment Resolution & Reissue Stormwater Management Plan | 2023-09-05 → 2026-08-31 (+1091d) | 2023-09-19 → 2026-09-15 (+1092d) | 448.6d → 433.6d |
| 12 | **Geotechnical Instrumentation & Monitoring Plan** | 2023-07-24 → 2026-07-20 (+1092d) | 2023-09-29 → 2026-09-25 (+1092d) |  |
| ContractNo_1580 | Prepare & Submit Geotechnical Instrumentation & Monitoring Plan | 2023-07-24 → 2026-07-20 (+1092d) | 2023-08-18 → 2026-08-14 (+1092d) | 440d → 422d |
| ContractNo_1590 | Review & Approve Geotechnical Instrumentation & Monitoring Plan | 2023-08-19 → 2026-08-15 (+1092d) | 2023-09-17 → 2026-09-13 (+1092d) | 645d → 620d |
| ContractNo_1600 | Install Geotechnical & Monitoring Instrumentation | 2023-09-18 → 2026-09-14 (+1092d) | 2023-09-29 → 2026-09-25 (+1092d) | 440d → 425d |
| 6 | **Quality Control Plans** | 2023-07-24 → 2026-07-20 (+1092d) | 2023-10-18 → 2026-10-14 (+1092d) |  |
| 1 | **Drilled Shaft Quality Control Plan** | 2023-07-24 → 2026-07-20 (+1092d) | 2023-10-18 → 2026-10-14 (+1092d) |  |
| ContractNo_2400 | Prepare & Submit Drilled Shaft Quality Control Plan | 2023-07-24 → 2026-07-20 (+1092d) | 2023-09-18 → 2026-09-14 (+1092d) | 429d → 414d |
| ContractNo_2410 | Review & Approve Drilled Shaft Quality Control Plan | 2023-09-19 → 2026-09-15 (+1092d) | 2023-10-18 → 2026-10-14 (+1092d) | 629d → 605d |
| 2 | **Deck Membrane Waterproofing** | 2023-07-24 → 2026-07-20 (+1092d) | 2023-10-18 → 2026-10-14 (+1092d) |  |
| ContractNo_2420 | Prepare & Submit Deck Membrane Waterproofing Quality Control Plan | 2023-07-24 → 2026-07-20 (+1092d) | 2023-09-18 → 2026-09-14 (+1092d) | 429d → 414d |
| ContractNo_2430 | Review & Approve Deck Membrane Waterproofing Quality Control Plan | 2023-09-19 → 2026-09-15 (+1092d) | 2023-10-18 → 2026-10-14 (+1092d) | 629d → 605d |
| 3 | **Earthwork** | 2023-07-24 → 2026-07-20 (+1092d) | 2023-10-18 → 2026-10-14 (+1092d) |  |
| ContractNo_2440 | Prepare & Submit Earthwork Quality Control Plan | 2023-07-24 → 2026-07-20 (+1092d) | 2023-09-18 → 2026-09-14 (+1092d) | 429d → 414d |
| ContractNo_2450 | Review & Approve Earthwork Quality Control Plan | 2023-09-19 → 2026-09-15 (+1092d) | 2023-10-18 → 2026-10-14 (+1092d) | 629d → 605d |
| 4 | **HMA Pavement** | 2023-07-24 → 2026-07-20 (+1092d) | 2023-10-18 → 2026-10-14 (+1092d) |  |
| ContractNo_2460 | Prepare & Submit HMA Pavement Quality Control Plan | 2023-07-24 → 2026-07-20 (+1092d) | 2023-09-18 → 2026-09-14 (+1092d) | 429d → 414d |

| ID | Task | Start | Finish | Total float |
| --- | --- | --- | --- | --- |
| ContractNo_2470 | Review & Approve HMA Pavement Quality Control Plan | 2023-09-19 → 2026-09-15 (+1092d) | 2023-10-18 → 2026-10-14 (+1092d) | 629d → 605d |
| 5 | **Portland Cement Concrete - Cast in Place Elements** | 2023-07-24 → 2026-07-20 (+1092d) | 2023-10-18 → 2026-10-14 (+1092d) |  |
| ContractNo_2480 | Prepare & Submit Portland Cement Concrete - Cast in Place Elements Quality Control Plan | 2023-07-24 → 2026-07-20 (+1092d) | 2023-09-18 → 2026-09-14 (+1092d) | 429d → 414d |
| ContractNo_2490 | Review & Approve Portland Cement Concrete - Cast in Place Elements Quality Control Plan | 2023-09-19 → 2026-09-15 (+1092d) | 2023-10-18 → 2026-10-14 (+1092d) | 629d → 605d |
| 6 | **Structural Steel Element** | 2023-07-24 → 2026-07-20 (+1092d) | 2023-10-18 → 2026-10-14 (+1092d) |  |
| ContractNo_2500 | Prepare & Submit Structural Steel Element Quality Control Plan | 2023-07-24 → 2026-07-20 (+1092d) | 2023-09-18 → 2026-09-14 (+1092d) | 429d → 414d |
| ContractNo_2510 | Review & Approve Structural Steel Element Quality Control Plan | 2023-09-19 → 2026-09-15 (+1092d) | 2023-10-18 → 2026-10-14 (+1092d) | 629d → 605d |
| 7 | **Construction Submittals** | 2023-07-24 → 2026-07-20 (+1092d) | 2024-03-15 → 2027-03-12 (+1092d) |  |
| 2 | **Traffic Management Plan (TTCP)** | 2023-07-24 → 2026-07-20 (+1092d) | 2023-11-02 → 2026-10-29 (+1092d) |  |
| ContractNo_1900 | Prepare Traffic Management Plan (Stage 1) | 2023-07-24 → 2026-07-20 (+1092d) | 2023-09-11 → 2026-09-04 (+1089d) | 46d → 23.4d |
| ContractNo_1910 | Schedule & Conduct OTS Review - Traffic Management Plan (Stage 1) | 2023-09-12 → 2026-09-08 (+1092d) | 2023-09-13 → 2026-09-09 (+1092d) | 46d → 23.4d |
| ContractNo_1810 | Submit Traffic Management Plan (Stage 1) | 2023-09-14 → 2026-09-10 (+1092d) | 2023-09-19 → 2026-09-15 (+1092d) | 46d → 23.4d |
| ContractNo_2030 | Review & Approve Traffic Management Plan (Stage 1) | 2023-09-20 → 2026-09-16 (+1092d) | 2023-10-19 → 2026-10-15 (+1092d) | 68d → 34.4d |
| ContractNo_1820 | Comment Resolution & Reissue Traffic Management Plan | 2023-10-20 → 2026-10-16 (+1092d) | 2023-11-02 → 2026-10-29 (+1092d) | 46d → 32d |
| 11 | **Existing Bridge Monitoring Plan** | 2023-07-24 → 2026-07-20 (+1092d) | 2023-08-18 → 2026-08-14 (+1092d) |  |
| ContractNo_2210 | Prepare & Submit Existing Bridge Monitoring Plan | 2023-07-24 → 2026-07-20 (+1092d) | 2023-08-18 → 2026-08-14 (+1092d) | 214d → 200d |
| 12 | **Dewatering Plan** | 2023-07-24 → 2026-07-20 (+1092d) | 2023-11-01 → 2026-10-28 (+1092d) |  |
| ContractNo_2380 | Prepare & Submit Dewatering Plan | 2023-07-24 → 2026-07-20 (+1092d) | 2023-10-02 → 2026-09-28 (+1092d) | 419d → 404d |
| ContractNo_2390 | Review & Approve Dewatering Plan | 2023-10-03 → 2026-09-29 (+1092d) | 2023-11-01 → 2026-10-28 (+1092d) | 615d → 591d |
| 6 | **Demolition Plan - NB** | 2023-07-24 → 2026-07-20 (+1092d) | 2023-12-29 → 2026-12-25 (+1092d) |  |
| ContractNo_2170 | Prepare & Submit Demolition Plan | 2023-07-24 → 2026-07-20 (+1092d) | 2023-11-29 → 2026-11-25 (+1092d) | 123d → 111d |
| ContractNo_2180 | Review & Approve Demolition Plan | 2023-11-30 → 2026-11-26 (+1092d) | 2023-12-29 → 2026-12-25 (+1092d) | 181d → 163d |
| 13 | **Drilled Shaft Installation/Testing Procedure** | 2023-07-24 → 2026-07-20 (+1092d) | 2023-11-30 → 2026-11-26 (+1092d) |  |
| ContractNo_2240 | Prepare & Submit Drilled Shaft Installation/Testing Procedure | 2023-07-24 → 2026-07-20 (+1092d) | 2023-10-31 → 2026-10-27 (+1092d) | 399d → 384d |
| ContractNo_2250 | Review & Approve Drilled Shaft Installation/Testing Procedure | 2023-11-01 → 2026-10-28 (+1092d) | 2023-11-30 → 2026-11-26 (+1092d) | 586d → 562d |
| 5 | **Abutment Pile Intsallation Plan** | 2023-07-24 → 2026-07-20 (+1092d) | 2023-10-18 → 2026-10-14 (+1092d) |  |
| ContractNo_2260 | Prepare & Submit Abutment Pile Installation Plan | 2023-07-24 → 2026-07-20 (+1092d) | 2023-09-18 → 2026-09-14 (+1092d) | 429d → 414d |
| ContractNo_2270 | Review & Approve Abutment Pile Installation Plan | 2023-09-19 → 2026-09-15 (+1092d) | 2023-10-18 → 2026-10-14 (+1092d) | 629d → 605d |
| 7 | **Erection Plan - Stage 1** | 2023-07-24 → 2026-07-20 (+1092d) | 2023-11-16 → 2026-11-12 (+1092d) |  |
| ContractNo_2190 | Prepare & Submit Erection Plan - Stage 1 | 2023-07-24 → 2026-07-20 (+1092d) | 2023-10-17 → 2026-10-13 (+1092d) | 175d → 161d |
| ContractNo_2200 | Review & Approve Erection Plan - Stage 1 | 2023-10-18 → 2026-10-14 (+1092d) | 2023-11-16 → 2026-11-12 (+1092d) | 257d → 237d |
| 3 | **Erection Plan - Stage 2** | 2023-11-17 → 2026-11-13 (+1092d) | 2024-03-15 → 2027-03-12 (+1092d) |  |
| ContractNo_2280 | Prepare & Submit Erection Plan - Stage 2 | 2023-11-17 → 2026-11-13 (+1092d) | 2024-02-14 → 2027-02-10 (+1092d) | 327d → 313d |
| ContractNo_2290 | Review & Approve Erection Plan - Stage 2 | 2024-02-15 → 2027-02-11 (+1092d) | 2024-03-15 → 2027-03-12 (+1092d) | 480d → 456d |
| 4 | **Erection Plan - Stage 3** | 2023-07-24 → 2026-07-20 (+1092d) | 2023-11-16 → 2026-11-12 (+1092d) |  |
| ContractNo_2300 | Prepare & Submit Erection Plan - Stage 3 | 2023-07-24 → 2026-07-20 (+1092d) | 2023-10-17 → 2026-10-13 (+1092d) | 409d → 394d |
| ContractNo_2310 | Review & Approve Erection Plan - Stage 3 | 2023-10-18 → 2026-10-14 (+1092d) | 2023-11-16 → 2026-11-12 (+1092d) | 600d → 576d |
| 10 | **Deck Placement Plan** | 2023-07-24 → 2026-07-20 (+1092d) | 2023-12-29 → 2026-12-25 (+1092d) |  |
| ContractNo_2320 | Prepare & Submit Deck Placement Plan | 2023-07-24 → 2026-07-20 (+1092d) | 2023-11-29 → 2026-11-25 (+1092d) | 379d → 364d |
| ContractNo_2330 | Review & Approve Deck Placement Plan | 2023-11-30 → 2026-11-26 (+1092d) | 2023-12-29 → 2026-12-25 (+1092d) | 557d → 533d |
| 8 | **Solid Pier Wall Construction Plan** | 2023-07-24 → 2026-07-20 (+1092d) | 2023-11-16 → 2026-11-12 (+1092d) |  |
| ContractNo_2340 | Prepare & Submit Solid Pier Wall Construction Plan | 2023-07-24 → 2026-07-20 (+1092d) | 2023-10-17 → 2026-10-13 (+1092d) | 409d → 394d |
| ContractNo_2350 | Review & Approve Solid Pier Wall Construction Plan | 2023-10-18 → 2026-10-14 (+1092d) | 2023-11-16 → 2026-11-12 (+1092d) | 600d → 576d |
| 9 | **Formwork Plan** | 2023-07-24 → 2026-07-20 (+1092d) | 2023-11-16 → 2026-11-12 (+1092d) |  |
| ContractNo_2360 | Prepare & Submit Formwork Plan | 2023-07-24 → 2026-07-20 (+1092d) | 2023-10-17 → 2026-10-13 (+1092d) | 409d → 394d |
| ContractNo_2370 | Review & Approve Formwork Plan | 2023-10-18 → 2026-10-14 (+1092d) | 2023-11-16 → 2026-11-12 (+1092d) | 600d → 576d |
| 8 | **Shop Drawings and Procurements** | 2023-07-24 → 2026-07-20 (+1092d) | 2024-03-24 → 2027-03-21 (+1092d) |  |
| 16 | **Superstructure Rebar Design** | 2023-07-24 → 2026-07-20 (+1092d) | 2023-10-25 → 2026-10-21 (+1092d) |  |
| ContractNo_3040 | Prepare & Submit Early Release Superstructure Rebar Design | 2023-07-24 → 2026-07-20 (+1092d) | 2023-09-25 → 2026-09-21 (+1092d) | 333d → 316d |
| ContractNo_3050 | Review & Approve Early Release Superstructure Rebar Design | 2023-09-26 → 2026-09-22 (+1092d) | 2023-10-25 → 2026-10-21 (+1092d) | 490d → 463d |
| 9 | **Abutment Rebar** | 2023-07-24 → 2026-07-20 (+1092d) | 2023-10-17 → 2026-10-13 (+1092d) |  |
| ContractNo_3010 | Prepare & Submit Substructure Rebar Shop Drawings | 2023-07-24 → 2026-07-20 (+1092d) | 2023-08-18 → 2026-08-14 (+1092d) | 430d → 413d |
| ContractNo_3020 | Review & Approve Substructure Rebar Shop Drawings | 2023-08-19 → 2026-08-15 (+1092d) | 2023-09-17 → 2026-09-13 (+1092d) | 630d → 606d |
| ContractNo_3030 | Procure Substructure Rebar | 2023-09-18 → 2026-09-14 (+1092d) | 2023-10-17 → 2026-10-13 (+1092d) | 630d → 606d |
| 14 | **Drilled Shaft Rebar** | 2023-07-24 → 2026-07-20 (+1092d) | 2023-10-17 → 2026-10-13 (+1092d) |  |
| ContractNo_3510 | Prepare & Submit Drilled Shaft Rebar Shop Drawings | 2023-07-24 → 2026-07-20 (+1092d) | 2023-08-18 → 2026-08-14 (+1092d) | 430d → 413d |
| ContractNo_3520 | Review & Approve Drilled Shaft Rebar Shop Drawings | 2023-08-19 → 2026-08-15 (+1092d) | 2023-09-17 → 2026-09-13 (+1092d) | 630d → 606d |
| ContractNo_3530 | Procure Drilled Shaft Rebar | 2023-09-18 → 2026-09-14 (+1092d) | 2023-10-17 → 2026-10-13 (+1092d) | 630d → 606d |
| 15 | **Pier Substructure Rebar** | 2023-07-24 → 2026-07-20 (+1092d) | 2023-11-01 → 2026-10-28 (+1092d) |  |
| ContractNo_3540 | Prepare & Submit Pier Substructure Rebar Shop Drawings | 2023-07-24 → 2026-07-20 (+1092d) | 2023-08-18 → 2026-08-14 (+1092d) | 419d → 402d |
| ContractNo_3550 | Review & Approve Pier Substructure Rebar Shop Drawings | 2023-08-19 → 2026-08-15 (+1092d) | 2023-09-17 → 2026-09-13 (+1092d) | 615d → 591d |
| ContractNo_3560 | Procure Pier Substructure Rebar | 2023-09-18 → 2026-09-14 (+1092d) | 2023-11-01 → 2026-10-28 (+1092d) | 615d → 591d |
| 3 | **Stay in Place Formwork** | 2023-07-24 → 2026-07-20 (+1092d) | 2023-11-16 → 2026-11-12 (+1092d) |  |
| ContractNo_3330 | Prepare & Submit Stay in Place Formwork | 2023-07-24 → 2026-07-20 (+1092d) | 2023-08-18 → 2026-08-14 (+1092d) | 409d → 391d |
| ContractNo_3340 | Review & Approve Stay in Place Formwork | 2023-08-19 → 2026-08-15 (+1092d) | 2023-09-17 → 2026-09-13 (+1092d) | 600d → 576d |
| ContractNo_3350 | Procure Stay in Place Formwork | 2023-09-18 → 2026-09-14 (+1092d) | 2023-11-16 → 2026-11-12 (+1092d) | 600d → 576d |
| 7 | **Solid Pier Wall (Pier Bases) Design & Shop Drawings** | 2023-07-24 → 2026-07-20 (+1092d) | 2024-03-24 → 2027-03-21 (+1092d) |  |
| ContractNo_3130 | Prepare & Submit - Solid Pier Wall (Pier Bases) Design | 2023-07-24 → 2026-07-20 (+1092d) | 2023-10-17 → 2026-10-13 (+1092d) | 322d → 304d |
| ContractNo_3140 | Review & Approve - Solid Pier Wall (Pier Bases) Design | 2023-10-18 → 2026-10-14 (+1092d) | 2023-11-16 → 2026-11-12 (+1092d) | 472d → 447d |
| ContractNo_3070 | Prepare & Submit - Solid Pier Wall (Pier Bases) Shop Drawings | 2023-11-17 → 2026-11-13 (+1092d) | 2023-12-15 → 2026-12-11 (+1092d) | 319d → 304d |

| ID | Task | Start | Finish | Total float |
| --- | --- | --- | --- | --- |
| ContractNo_3080 | Review & Approve Solid Pier Wall Shop Drawings | 2023-12-16 → 2026-12-12 (+1092d) | 2024-01-14 → 2027-01-10 (+1092d) | 471d → 447d |
| ContractNo_3090 | Procure Solid Pier Wall Material | 2024-01-15 → 2027-01-11 (+1092d) | 2024-03-24 → 2027-03-21 (+1092d) | 471d → 447d |
| 5 | **Drainage Structures** | 2023-07-24 → 2026-07-20 (+1092d) | 2023-10-12 → 2026-10-08 (+1092d) |  |
| ContractNo_3100 | Prepare & Submit Drainage Structures | 2023-07-24 → 2026-07-20 (+1092d) | 2023-08-18 → 2026-08-14 (+1092d) | 433d → 416d |
| ContractNo_3110 | Review & Approve Drainage Structures | 2023-08-19 → 2026-08-15 (+1092d) | 2023-09-17 → 2026-09-13 (+1092d) | 635d → 611d |
| ContractNo_3120 | Procure Drainage Structures | 2023-09-18 → 2026-09-14 (+1092d) | 2023-10-12 → 2026-10-08 (+1092d) | 635d → 611d |
| 1 | **TL-5 Pier Protection Barrier** | 2023-07-24 → 2026-07-20 (+1092d) | 2023-10-22 → 2026-10-18 (+1092d) |  |
| ContractNo_3160 | Prepare & Submit TL-5 Pier Protection Barrier | 2023-07-24 → 2026-07-20 (+1092d) | 2023-08-18 → 2026-08-14 (+1092d) | 425d → 410d |
| ContractNo_3170 | Review & Approve TL-5 Pier Protection Barrier | 2023-08-19 → 2026-08-15 (+1092d) | 2023-09-17 → 2026-09-13 (+1092d) | 625d → 601d |
| ContractNo_3180 | Procure TL-5 Pier Protection Barrier | 2023-09-18 → 2026-09-14 (+1092d) | 2023-10-22 → 2026-10-18 (+1092d) | 625d → 601d |
| 12 | **Bridge Bearings** | 2023-07-24 → 2026-07-20 (+1092d) | 2023-11-30 → 2026-11-26 (+1092d) |  |
| ContractNo_3220 | Prepare & Submit Bridge Bearings Shop Drawings | 2023-07-24 → 2026-07-20 (+1092d) | 2023-09-01 → 2026-08-28 (+1092d) | 399d → 381d |
| ContractNo_3230 | Review & Approve Bridge Bearings Shop Drawings | 2023-09-02 → 2026-08-29 (+1092d) | 2023-10-01 → 2026-09-27 (+1092d) | 586d → 562d |
| ContractNo_3190 | Procure Bridge Bearings | 2023-10-02 → 2026-09-28 (+1092d) | 2023-11-30 → 2026-11-26 (+1092d) | 586d → 562d |
| 4 | **Superstructure Rebar** | 2023-10-26 → 2026-10-22 (+1092d) | 2024-03-06 → 2027-03-04 (+1093d) |  |
| ContractNo_3360 | Prepare & Submit Superstructure Rebar Shop Drawings | 2023-10-26 → 2026-10-22 (+1092d) | 2023-12-07 → 2026-12-04 (+1093d) | 333d → 315d |
| ContractNo_3370 | Review & Approve Superstructure Rebar Shop Drawings | 2023-12-08 → 2026-12-05 (+1093d) | 2024-01-06 → 2027-01-03 (+1093d) | 489d → 464d |
| ContractNo_3060 | Procure Superstructure Rebar | 2024-01-07 → 2027-01-04 (+1093d) | 2024-03-06 → 2027-03-04 (+1093d) | 489d → 464d |
| 6 | **Bridge Scuppers** | 2023-07-24 → 2026-07-20 (+1092d) | 2023-11-30 → 2026-11-26 (+1092d) |  |
| ContractNo_3380 | Prepare & Submit Bridge Scupper Shop Drawings | 2023-07-24 → 2026-07-20 (+1092d) | 2023-09-01 → 2026-08-28 (+1092d) | 399d → 381d |
| ContractNo_3390 | Review & Approve Bridge Scupper Shop Drawings | 2023-09-02 → 2026-08-29 (+1092d) | 2023-10-01 → 2026-09-27 (+1092d) | 586d → 562d |
| ContractNo_3200 | Procure/Fabricate Bridge Scuppers | 2023-10-02 → 2026-09-28 (+1092d) | 2023-11-30 → 2026-11-26 (+1092d) | 586d → 562d |
| 8 | **Bridge Joint** | 2023-07-24 → 2026-07-20 (+1092d) | 2023-11-30 → 2026-11-26 (+1092d) |  |
| ContractNo_3400 | Prepare & Submit Bridge Shop Drawings | 2023-07-24 → 2026-07-20 (+1092d) | 2023-09-01 → 2026-08-28 (+1092d) | 399d → 381d |
| ContractNo_3410 | Review & Approve Bridge Joint Design | 2023-09-02 → 2026-08-29 (+1092d) | 2023-10-01 → 2026-09-27 (+1092d) | 586d → 562d |
| ContractNo_3210 | Procure/Fabricate Bridge Joint | 2023-10-02 → 2026-09-28 (+1092d) | 2023-11-30 → 2026-11-26 (+1092d) | 586d → 562d |
| 9 | **Early Action Permit Plan Changes** | 2023-07-24 → 2026-07-20 (+1092d) | 2023-10-30 → 2026-10-26 (+1092d) |  |
| 1 | **National Marine Fishery Service (NMFS)** | 2023-07-24 → 2026-07-20 (+1092d) | 2023-10-29 → 2026-10-25 (+1092d) |  |
| ContractNo_1300 | Prepare & Submit Revised Section 7 Letter | 2023-07-24 → 2026-07-20 (+1092d) | 2023-08-25 → 2026-08-21 (+1092d) | 177d → 0d |
| ContractNo_1310 | Review & Approve Revised Section 7 Letter | 2023-08-26 → 2026-08-22 (+1092d) | 2023-09-24 → 2026-09-20 (+1092d) | 260d → 0d |
| ContractNo_1330 | Comment Resolution & Reissue Revised Section 7 Letter | 2023-09-25 → 2026-09-21 (+1092d) | 2023-09-29 → 2026-09-25 (+1092d) | 178d → 0d |
| ContractNo_1320 | NMFS - Review & Approve Revised Section 7 Letter | 2023-09-30 → 2026-09-26 (+1092d) | 2023-10-29 → 2026-10-25 (+1092d) | 617d → 592d |
| 11 | **Water Quality Certification Permit Plan Changes** | 2023-07-24 → 2026-07-20 (+1092d) | 2023-10-30 → 2026-10-26 (+1092d) |  |
| ContractNo_1220 | Prepare & Submit WQC Permit Plan Changes | 2023-07-24 → 2026-07-20 (+1092d) | 2023-08-18 → 2026-08-14 (+1092d) | 425d → 406d |
| ContractNo_1240 | Review & Approve WQC Permit Plan Changes | 2023-08-19 → 2026-08-15 (+1092d) | 2023-09-17 → 2026-09-13 (+1092d) | 623d → 597d |
| ContractNo_1280 | Comment Resolution & Reissue WQC Permit Plan Changes | 2023-09-18 → 2026-09-14 (+1092d) | 2023-09-22 → 2026-09-18 (+1092d) | 425d → 408d |
| ContractNo_1260 | MassDEP - Review & Approve WQC Permit Plan Changes | 2023-09-22 → 2026-09-18 (+1092d) | 2023-10-22 → 2026-10-18 (+1092d) | 624.67d → 599.67d |
| ContractNo_1340 | MassDEP - Issue WQC Permit Plan Changes | 2023-10-30 → 2026-10-26 (+1092d) | 2023-10-30 → 2026-10-26 (+1092d) | 420d → 405d |
| 12 | **Army Corp of Engineers Permit Plan Changes** | 2023-07-24 → 2026-07-20 (+1092d) | 2023-10-30 → 2026-10-26 (+1092d) |  |
| ContractNo_1230 | Prepare & Submit ACOE Permit Plan Changes | 2023-07-24 → 2026-07-20 (+1092d) | 2023-08-15 → 2026-08-11 (+1092d) | 428d → 409d |
| ContractNo_1250 | Review & Approve ACOE Permit Plan Changes | 2023-08-16 → 2026-08-12 (+1092d) | 2023-09-14 → 2026-09-10 (+1092d) | 626d → 600d |
| ContractNo_1290 | Comment Resolution & Reissue ACOE Permit Plan Changes | 2023-09-15 → 2026-09-11 (+1092d) | 2023-09-21 → 2026-09-17 (+1092d) | 426d → 409d |
| ContractNo_1270 | ACOE - Review & Approve ACOE Permit Plan Changes | 2023-09-21 → 2026-09-17 (+1092d) | 2023-10-21 → 2026-10-17 (+1092d) | 625.67d → 600.67d |
| ContractNo_1350 | ACOE - Issue ACOE Permit Plan Changes | 2023-10-30 → 2026-10-26 (+1092d) | 2023-10-30 → 2026-10-26 (+1092d) | 420d → 405d |
| Uti | **Utility** | 2023-08-02 → 2026-07-29 (+1092d) | 2024-04-10 → 2027-04-08 (+1093d) |  |
| URP | **Utility Relocation & Coordination Plan** | 2023-08-02 → 2026-07-29 (+1092d) | 2023-08-22 → 2026-08-18 (+1092d) |  |
| ContractNo_P250 | Prepare & Submit - Early Utiltiy Relocation Request\Coordination Plan | 2023-08-02 → 2026-07-29 (+1092d) | 2023-08-15 → 2026-08-11 (+1092d) | 125d → 77.4d |
| ContractNo_P260 | Review & Approve - Early Utiltiy Relocation Request\Coordination Plan | 2023-08-16 → 2026-08-12 (+1092d) | 2023-08-22 → 2026-08-18 (+1092d) | 125d → 77.4d |
| Not | **Utility Notifications & Meetings** | 2023-08-23 → 2026-08-19 (+1092d) | 2023-09-21 → 2026-09-17 (+1092d) |  |
| ContractNo_U100 | Coordinate/Mobilization Period - Relocation w/ Utility Company - [insert Utility 1 Name] | 2023-08-23 → 2026-08-19 (+1092d) | 2023-09-21 → 2026-09-17 (+1092d) | 125d → 77.4d |
| ContractNo_U350 | Coordinate/Mobilization Period - Relocation w/ Utility Company - [insert Utility 2 Name] | 2023-08-23 → 2026-08-19 (+1092d) | 2023-09-21 → 2026-09-17 (+1092d) | 161d → 116.4d |
| ContractNo_U360 | Coordinate/Mobilization Period - Relocation w/ Utility Company - [insert Utility 3 Name] | 2023-08-23 → 2026-08-19 (+1092d) | 2023-09-21 → 2026-09-17 (+1092d) | 196d → 153.4d |
| ContractNo_U370 | Coordinate/Mobilization Period - Relocation w/ Utility Company - [insert Utility 4 Name] | 2023-08-23 → 2026-08-19 (+1092d) | 2023-09-21 → 2026-09-17 (+1092d) | 234d → 188.4d |
| Rel | **Utility Relocation** | 2023-11-15 → 2026-11-12 (+1093d) | 2024-04-10 → 2027-04-08 (+1093d) |  |
| 1 | **Utility 1 PUC Tasks** | 2023-11-15 → 2026-11-12 (+1093d) | 2023-12-21 → 2026-12-18 (+1093d) |  |
| ContractNo_U340 | Utility 1 Task 1: Copy Activity Name from PUC Form | 2023-11-15 → 2026-11-12 (+1093d) | 2023-12-14 → 2026-12-11 (+1093d) | 46.6d → 15d |
| ContractNo_U120 | Utility 1 Task 2: Copy Activity Name from PUC Form | 2023-12-14 → 2026-12-11 (+1093d) | 2023-12-21 → 2026-12-18 (+1093d) | 46.6d → 15d |
| 2 | **Utility 2 PUC Tasks** | 2023-12-21 → 2026-12-18 (+1093d) | 2024-01-30 → 2027-01-27 (+1093d) |  |
| ContractNo_U380 | Utility 2 Task 1: Copy Activity Name from PUC Form | 2023-12-21 → 2026-12-18 (+1093d) | 2024-01-23 → 2027-01-20 (+1093d) | 46.6d → 15d |
| ContractNo_U390 | Utility 2 Task 2: Copy Activity Name from PUC Form | 2024-01-23 → 2027-01-20 (+1093d) | 2024-01-30 → 2027-01-27 (+1093d) | 46.6d → 15d |
| 3 | **Utility 3 PUC Tasks** | 2024-01-30 → 2027-01-27 (+1093d) | 2024-03-06 → 2027-03-04 (+1093d) |  |
| ContractNo_U400 | Utility 3 Task 1: Copy Activity Name from PUC Form | 2024-01-30 → 2027-01-27 (+1093d) | 2024-02-28 → 2027-02-25 (+1093d) | 46.6d → 15d |
| ContractNo_U410 | Utility 3 Task 2: Copy Activity Name from PUC Form | 2024-02-28 → 2027-02-25 (+1093d) | 2024-03-06 → 2027-03-04 (+1093d) | 46.6d → 15d |
| 4 | **Utility 4 PUC Tasks** | 2024-03-06 → 2027-03-04 (+1093d) | 2024-04-10 → 2027-04-08 (+1093d) |  |
| ContractNo_U420 | Utility 4 Task 1: Copy Activity Name from PUC Form | 2024-03-06 → 2027-03-04 (+1093d) | 2024-04-03 → 2027-04-01 (+1093d) | 46.6d → 15d |
| ContractNo_U430 | Utility 4 Task 2: Copy Activity Name from PUC Form | 2024-04-03 → 2027-04-01 (+1093d) | 2024-04-10 → 2027-04-08 (+1093d) | 46.6d → 15d |
| ServConn | **Utility Service Connections** | 2023-08-02 → 2026-07-29 (+1092d) | 2023-09-13 → 2026-09-10 (+1093d) |  |
| ContractNo_U440 | Design-Builder Request WO# for Service Connection @ Location XXX (If Required) | 2023-08-02 → 2026-07-29 (+1092d) | 2023-08-08 → 2026-08-04 (+1092d) | 93d → 61d |
| ContractNo_U450 | Utility Assigns WO# for Service Connection @ Location XXX (If Required) | 2023-08-09 → 2026-08-05 (+1092d) | 2023-08-15 → 2026-08-11 (+1092d) | 93d → 61d |
| ContractNo_U460 | Utility Completes Design and Requests Payment for WO# @ Location XXX (If Required) | 2023-08-15 → 2026-08-11 (+1092d) | 2023-09-04 → 2026-08-31 (+1092d) | 135.67d → 87.8d |

| ID | Task | Start | Finish | Total float |
| --- | --- | --- | --- | --- |
| ContractNo_U470 | Design-Builder installs UG conduit @ Location XXX (If Required) | 2023-09-05 → 2026-09-01 (+1092d) | 2023-09-11 → 2026-09-08 (+1093d) | 92d → 59.4d |
| ContractNo_U480 | Utility Performs Service Connection @ Location XXX (If Required) | 2023-09-12 → 2026-09-09 (+1093d) | 2023-09-13 → 2026-09-10 (+1093d) |  |
| Con | **Construction** | 2023-01-03 → 2026-01-02 (+1095d) | 2025-05-01 → 2028-05-02 (+1097d) |  |
| Gene | **General** | 2023-07-24 → 2026-07-20 (+1092d) | 2023-08-02 → 2026-07-29 (+1092d) |  |
| ContractNo_PCM1 | Schedule Pre-Construction Meeting/Schedule Planning Session | 2023-07-24 → 2026-07-20 (+1092d) | 2023-08-01 → 2026-07-28 (+1092d) | 86d → 53.4d |
| ContractNo_PCM2 | Conduct Pre-Construction Meeting/Schedule Planning Session | 2023-08-02 → 2026-07-29 (+1092d) | 2023-08-02 → 2026-07-29 (+1092d) | 86d → 53.4d |
| Mobi | **Start-up** | 2023-01-03 → 2026-01-02 (+1095d) | 2023-11-15 → 2026-11-12 (+1093d) |  |
| ContractNo_C910 | MassDOT Baseline Survey / Layout of Utility Pole Locations | 2023-01-03 → 2026-01-02 (+1095d) | 2023-01-31 → 2026-01-30 (+1095d) | 240d → 205.4d |
| ContractNo_C070 | Design-Builder Mobilize | 2023-08-02 → 2026-07-29 (+1092d) | 2023-08-29 → 2026-08-25 (+1092d) | 90d → 58.4d |
| ContractNo_C100 | Establish Engineer's Field Office | 2023-08-02 → 2026-07-29 (+1092d) | 2023-08-29 → 2026-08-25 (+1092d) | 90d → 58.4d |
| ContractNo_C370 | Install Traffic Devices, RTTM System, Barriers, Signage | 2023-11-01 → 2026-10-28 (+1092d) | 2023-11-08 → 2026-11-04 (+1092d) | 46.6d → 15d |
| ContractNo_C080 | Install SWPPP Systems | 2023-11-08 → 2026-11-04 (+1092d) | 2023-11-15 → 2026-11-12 (+1093d) | 146.6d → 132.6d |
| ContractNo_C900 | Design-Builder Performs Utility Enabling Work (If Required) | 2023-11-08 → 2026-11-04 (+1092d) | 2023-11-15 → 2026-11-12 (+1093d) | 46.6d → 15d |
| Ph1 | **Stage 1** | 2024-04-10 → 2026-09-28 (+901d) | 2024-09-11 → 2027-09-01 (+1085d) |  |
| StpA | **Step A** | 2024-04-10 → 2026-09-28 (+901d) | 2024-07-15 → 2027-07-07 (+1087d) |  |
| ContractNo_C480 | Environmental Protection of Box Turtles | 2024-06-03 → 2026-09-28 (+847d) | 2024-06-07 → 2027-06-02 (+1090d) | 11d → 0d |
| ContractNo_C465 | Install Temporary Shielding - [Location] | 2024-04-10 → 2027-04-08 (+1093d) | 2024-04-22 → 2027-04-20 (+1093d) | 46.6d → 32.6d |
| ContractNo_C475 | Demo Existing Superstructure - [Location] | 2024-06-10 → 2027-06-03 (+1088d) | 2024-06-13 → 2027-06-08 (+1090d) | 13d → 2d |
| ContractNo_C485 | Install Water Control Measures - [Location] | 2024-06-10 → 2027-06-03 (+1088d) | 2024-06-17 → 2027-06-10 (+1088d) | 11d → 0d |
| ContractNo_C490 | Excavate Abutments & Surrounding Area - [Location] | 2024-06-18 → 2027-06-11 (+1088d) | 2024-06-28 → 2027-06-22 (+1089d) | 11d → 0d |
| ContractNo_C505 | Demo Existing Substructure - [Location] | 2024-07-01 → 2027-06-23 (+1087d) | 2024-07-09 → 2027-06-30 (+1086d) | 11d → 0d |
| ContractNo_C515 | Set & Grout Precast Abutments - [Location] (NOTE: Ensure Grout Cure Period is accounted for) | 2024-07-10 → 2027-07-01 (+1086d) | 2024-07-15 → 2027-07-07 (+1087d) | 11d → 0d |
| StpB | **Step B** | 2024-07-16 → 2027-07-08 (+1087d) | 2024-09-11 → 2027-09-01 (+1085d) |  |
| ContractNo_C525 | Install Steel Beams - [Location] | 2024-07-16 → 2027-07-08 (+1087d) | 2024-07-23 → 2027-07-15 (+1087d) | 11d → 0d |
| ContractNo_C535 | Install Precast Decks - [Location] | 2024-07-24 → 2027-07-16 (+1087d) | 2024-07-26 → 2027-07-20 (+1089d) | 11d → 0d |
| ContractNo_C920 | Postension Precast Decks - [Location] | 2024-07-29 → 2027-07-21 (+1087d) | 2024-07-29 → 2027-07-21 (+1087d) | 11d → 0d |
| ContractNo_C545 | Grout Precast Decks - [Location] (NOTE: Ensure Grout Cure Period is accounted for) | 2024-07-30 → 2027-07-22 (+1087d) | 2024-08-01 → 2027-07-26 (+1089d) | 11d → 0d |
| ContractNo_C555 | F/R/Pour Sidewalk Placement 1 - [Location] | 2024-08-02 → 2027-07-27 (+1089d) | 2024-08-07 → 2027-07-30 (+1087d) | 11d → 0d |
| ContractNo_C930 | 72 Hour Placement Cure Period for Sidewalks - [Location] | 2024-08-07 → 2027-07-30 (+1087d) | 2024-08-10 → 2027-08-02 (+1087d) | 15.67d → 1.67d |
| ContractNo_C940 | Sidewalk Placement 2 - [Location] | 2024-08-12 → 2027-08-03 (+1086d) | 2024-08-13 → 2027-08-04 (+1086d) | 10d → 1d |
| ContractNo_C950 | Full Cure Period for Sidewalks - [Location] | 2024-08-13 → 2027-08-04 (+1086d) | 2024-08-27 → 2027-08-18 (+1086d) | 14.67d → 1.67d |
| ContractNo_C575 | Install waterproofing - [Location] | 2024-08-28 → 2027-08-19 (+1086d) | 2024-08-30 → 2027-08-23 (+1088d) | 9d → 1d |
| ContractNo_C580 | Place Protective Course Pavement - [Location] | 2024-09-03 → 2027-08-24 (+1085d) | 2024-09-03 → 2027-08-24 (+1085d) | 9d → 1d |
| ContractNo_C565 | Install Railings - [Location] | 2024-09-04 → 2027-08-25 (+1085d) | 2024-09-09 → 2027-08-30 (+1085d) | 9d → 1d |
| ContractNo_C590 | Install Pavement Markers, Sign and Stripe - [Location] | 2024-09-04 → 2027-08-25 (+1085d) | 2024-09-05 → 2027-08-26 (+1085d) | 11d → 3d |
| ContractNo_C585 | Complete Phase 1 - [Location] | 2024-09-09 → 2027-08-30 (+1085d) | 2024-09-09 → 2027-08-30 (+1085d) | 9d → 1d |
| ContractNo_C595 | Set Jersey Barriers & Signage - [Location] | 2024-09-10 → 2027-08-31 (+1085d) | 2024-09-11 → 2027-09-01 (+1085d) | 88d → 1d |
| Ph2 | **Stage 2** | 2024-09-10 → 2027-08-31 (+1085d) | 2025-05-01 → 2028-05-02 (+1097d) |  |
| StpA | **Step A** | 2024-09-10 → 2027-08-31 (+1085d) | 2024-10-04 → 2027-09-27 (+1088d) |  |
| ContractNo_C755 | Install Water Control Measures - [Location] | 2024-09-10 → 2027-08-31 (+1085d) | 2024-09-17 → 2027-09-08 (+1086d) | 9d → 4d |
| ContractNo_C750 | Traffic Switch from Phase I - [Location] | 2024-09-12 → 2027-09-02 (+1085d) | 2024-09-13 → 2027-09-03 (+1085d) | 88d → 1d |
| ContractNo_C765 | Install Temporary Shielding - [Location] | 2024-09-16 → 2027-09-07 (+1086d) | 2024-09-20 → 2027-09-13 (+1088d) | 88d → 1d |
| ContractNo_C790 | Excavate Abutments & Surrounding Area - [Location] | 2024-09-18 → 2027-09-09 (+1086d) | 2024-09-27 → 2027-09-20 (+1088d) | 101d → 106d |
| ContractNo_C805 | Demo Existing Substructure - [Location] | 2024-09-23 → 2027-09-14 (+1086d) | 2024-09-30 → 2027-09-21 (+1086d) | 88d → 1d |
| ContractNo_C815 | Set & Grout Precast Abutments - [Location] (NOTE: Ensure Grout Cure Period is accounted for) | 2024-10-01 → 2027-09-22 (+1086d) | 2024-10-04 → 2027-09-27 (+1088d) | 88d → 1d |
| StpB | **Step B** | 2024-10-07 → 2027-09-28 (+1086d) | 2025-04-23 → 2028-04-20 (+1093d) |  |
| ContractNo_C825 | Install Steel Beams - [Location] | 2024-10-07 → 2027-09-28 (+1086d) | 2024-10-15 → 2027-10-05 (+1085d) | 88d → 1d |
| ContractNo_C835 | Install Precast Decks - [Location] | 2024-10-16 → 2027-10-06 (+1085d) | 2024-10-21 → 2027-10-12 (+1086d) | 88d → 1d |
| ContractNo_C960 | Postension Precast Decks - [Location] | 2024-10-22 → 2027-10-13 (+1086d) | 2024-10-22 → 2027-10-13 (+1086d) | 88d → 1d |
| ContractNo_C845 | Grout Precast Decks - [Location] | 2024-10-23 → 2027-10-14 (+1086d) | 2024-10-25 → 2027-10-18 (+1088d) | 88d → 1d |
| ContractNo_C855 | F/R/Pour Sidewalk Placement 1 - [Location] | 2024-10-28 → 2027-10-19 (+1086d) | 2024-10-29 → 2027-10-20 (+1086d) | 88d → 1d |
| ContractNo_C970 | 72 Hour Placement Cure Period for Sidewalks - [Location] | 2024-10-29 → 2027-10-20 (+1086d) | 2024-11-01 → 2027-10-23 (+1086d) | 132.67d → 1.67d |
| ContractNo_C980 | Sidewalk Placement 2 - [Location] | 2024-11-04 → 2027-10-25 (+1085d) | 2024-11-05 → 2027-10-26 (+1085d) | 88d → 0d |
| ContractNo_C990 | Full Cure Period for Sidewalks - [Location] | 2024-11-05 → 2027-10-26 (+1085d) | 2024-11-19 → 2027-11-09 (+1085d) | 132.67d → 0.67d |
| ContractNo_C875 | Install waterproofing - [Location] | 2025-04-01 → 2027-11-10 (+953d) | 2025-04-03 → 2027-11-15 (+956d) |  |
| ContractNo_C1000 | Place Protective Course Pavement - [Location] | 2025-04-04 → 2028-04-03 (+1095d) | 2025-04-08 → 2028-04-05 (+1093d) |  |
| ContractNo_C865 | Install Railings - [Location] | 2025-04-09 → 2028-04-06 (+1093d) | 2025-04-14 → 2028-04-11 (+1093d) |  |
| ContractNo_C880 | Place Base & Top Pavement - [Location] | 2025-04-15 → 2028-04-12 (+1093d) | 2025-04-18 → 2028-04-18 (+1096d) |  |
| ContractNo_C890 | Install Pavement Markers, Sign and Stripe - [Location] | 2025-04-22 → 2028-04-19 (+1093d) | 2025-04-23 → 2028-04-20 (+1093d) |  |
| ContractNo_C885 | Complete Phase 2 - [Location] | 2025-04-23 → 2028-04-20 (+1093d) | 2025-04-23 → 2028-04-20 (+1093d) |  |
| StpC | **Step C** | 2024-09-30 → 2027-09-21 (+1086d) | 2025-05-01 → 2028-05-02 (+1097d) |  |
| ContractNo_C190 | Approach Work - Raise Grades - [Location] | 2024-09-30 → 2027-09-21 (+1086d) | 2024-10-22 → 2027-10-13 (+1086d) | 101d → 106d |
| ContractNo_C200 | Repair Underground Drainage Structure - [Location] | 2024-10-23 → 2027-10-14 (+1086d) | 2024-10-29 → 2027-10-20 (+1086d) | 101d → 106d |
| ContractNo_C320 | Backfill & Grade - [Location] | 2024-10-30 → 2027-10-21 (+1086d) | 2024-11-15 → 2027-11-05 (+1085d) | 101d → 106d |
| ContractNo_C470 | Install Landscape, Sod, Etc. - [Location] | 2025-04-16 → 2028-04-18 (+1098d) | 2025-05-01 → 2028-05-02 (+1097d) |  |
| Clo | **Close-Out** | 2025-04-24 → 2028-04-21 (+1093d) | 2025-07-08 → 2028-06-10 (+1068d) |  |
| ContractNo_C340 | MassDOT Inspection & Generate Punchlist | 2025-04-24 → 2028-04-21 (+1093d) | 2025-05-22 → 2028-05-11 (+1085d) |  |
| ContractNo_C360 | Prepare & Submit Remaining Project Documentation | 2025-04-24 → 2028-04-21 (+1093d) | 2025-05-21 → 2028-05-18 (+1093d) | 21d → 15d |
| ContractNo_C330 | Complete Punchlist & Demobilize | 2025-05-23 → 2028-05-12 (+1085d) | 2025-07-08 → 2028-06-10 (+1068d) |  |
| Pla | **Placeholder** | 2023-01-01 → 2026-01-01 (+1096d) | 2024-11-30 → 2027-11-27 (+1092d) |  |

| ID | Task | Start | Finish | Total float |
| --- | --- | --- | --- | --- |
| ContractNo_CAL04 | Cal04-7d/24hr, No Holidays (Milestones) | 2023-01-01 → 2026-01-01 (+1096d) | 2023-04-11 → 2026-04-11 (+1096d) | 819.67d → 791.67d |
| ContractNo_CAL03A | Cal03A-7d/8hr/No Holidays | 2023-01-01 → 2026-01-01 (+1096d) | 2023-04-10 → 2026-04-10 (+1096d) | 820d → 792d |
| ContractNo_C&RP | Cost & Resource Placeholder | 2023-01-03 → 2026-01-02 (+1095d) | 2023-05-25 → 2026-05-27 (+1098d) | 527d → 509d |
| ContractNo_CAL01 | Cal01-5D/8Hr, 12 Hol | 2023-01-03 → 2026-01-02 (+1095d) | 2023-05-25 → 2026-05-27 (+1098d) | 527d → 509d |
| ContractNo_CAL02 | Cal02-6D/8Hr, 12 Hol | 2023-01-03 → 2026-01-02 (+1095d) | 2023-05-02 → 2026-05-01 (+1095d) | 657d → 633d |
| ContractNo_CAL03 | Cal03-7D/8Hr, 12 Hol | 2023-01-02 → 2026-01-02 (+1096d) | 2023-04-13 → 2026-04-13 (+1096d) | 789d → 760d |
| ContractNo_CAL06 | Cal06-5D/8Hr, 12 Hol - Mjr Rdwy | 2023-01-03 → 2026-01-02 (+1095d) | 2023-05-30 → 2026-05-29 (+1095d) | 506d → 490d |
| ContractNo_CAL07 | Cal07-6D/8Hr, 12 Hol - Mjr Rdwy | 2023-01-03 → 2026-01-02 (+1095d) | 2023-05-05 → 2026-05-05 (+1096d) | 612d → 592d |
| ContractNo_CAL08 | Cal08-7D/8Hr, 12 Hol - Mjr Rdwy | 2023-01-02 → 2026-01-02 (+1096d) | 2023-04-20 → 2026-04-17 (+1093d) | 722d → 696d |
| ContractNo_CAL10 | Cal10-Winter Ineff, 5D/12 Hol | 2023-01-03 → 2026-01-02 (+1095d) | 2023-06-16 → 2026-06-18 (+1098d) | 472d → 451d |
| ContractNo_CAL16 | Cal16-Water Access 2, 5D/12Hol | 2023-01-03 → 2026-01-02 (+1095d) | 2023-09-07 → 2026-09-09 (+1098d) |  |
| ContractNo_CAL05 | Cal05-MBTA Night No Hol | 2023-01-03 → 2026-01-02 (+1095d) | 2023-05-25 → 2026-05-27 (+1098d) | 527d → 509d |
| ContractNo_CAL19 | Cal19-Saturdays Only (Advertise) | 2023-01-07 → 2026-01-03 (+1092d) | 2024-11-30 → 2027-11-27 (+1092d) | 31d → 28d |
| ContractNo_CAL18 | Cal18-Weekend Shutdown | 2023-01-06 → 2026-01-09 (+1099d) | 2023-05-05 → 2026-05-08 (+1099d) | 634.25d → 618d |
| ContractNo_CAL11 | Cal11-Winter Shut 5D/8Hr, 12Hol | 2023-03-16 → 2026-03-16 (+1096d) | 2023-08-08 → 2026-08-06 (+1094d) | 334d → 317d |
| ContractNo_CAL11A | Cal11A-Winter Shut 5D/8Hr, 12Hol - Mjr Rdwy | 2023-01-03 → 2026-03-16 (+1168d) | 2023-05-30 → 2026-08-11 (+1169d) | 365d → 298d |
| ContractNo_CAL14 | Cal14-Planting, 5D/12Hol - Deciduous | 2023-03-21 → 2026-03-23 (+1098d) | 2023-11-28 → 2026-12-01 (+1099d) | 153d → 158d |
| ContractNo_CAL12 | Cal12-Paving, 5D/12 Hol | 2023-04-03 → 2026-04-01 (+1094d) | 2023-08-24 → 2026-08-24 (+1096d) | 280d → 261d |
| ContractNo_CAL12A | Cal12A-Paving, 5D/12 Hol - Mjr Rdwy | 2023-01-03 → 2026-04-01 (+1184d) | 2023-05-30 → 2026-08-27 (+1185d) | 329d → 248d |
| ContractNo_CAL17 | Cal17 - Reclaimation - 5d/12hol | 2023-04-18 → 2026-04-15 (+1093d) | 2023-09-08 → 2026-09-08 (+1096d) | 205d → 191d |
| ContractNo_CAL13 | Cal13-Planting, 5D/12Hol - Evergreen | 2023-04-18 → 2026-04-16 (+1094d) | 2024-05-23 → 2027-05-26 (+1098d) | 77d → 76d |
| ContractNo_CAL15 | Cal15-Water Access1, 5D/12Hol | 2023-06-01 → 2026-06-01 (+1096d) | 2024-06-25 → 2027-06-21 (+1091d) | 92d → 78d |
